# 3GPP_Work Plan

Schedule from MS Project, 2000-01-03 to 2004-04-23, A marks actual dates.

## Calendars

- Standard: Mon-Fri 08:00-12:00, 13:00-17:00; Sat-Sun off.

## Resources

| Resource | Cost per use |
| --- | --- |
| NP | 89270560 |
| N1 |  |
| N2 |  |
| N3 |  |
| N4 |  |
| N5 |  |
| TP |  |
| T1 |  |
| T2 |  |
| T3 |  |
| RP |  |
| R1 |  |
| R2 |  |
| R3 |  |
| R4 |  |
| SP |  |
| S1 |  |
| S2 |  |
| S3 |  |
| S4 |  |
| S5 |  |
| PCG |  |
| GP |  |
| No |  |
| CN4 |  |
| ? |  |
| WG G2 |  |
| G2 |  |
| G1 |  |
| G4 |  |
| G3 |  |
| All |  |
| Generic |  |
| MLST |  |
| G5 |  |
| S3, G2 |  |
| WG T2 |  |
| GP,G1 |  |
| G4,G5 |  |

## Schedule

| ID | WBS | Task | Duration | Start | Finish | Complete | Remaining | Baseline start | Baseline finish | Baseline duration | Total slack | Constraint | Resources | Work | Actual work | Text6 | Text9 | Text1 | Text4 | Text7 | Text8 | Text2 | Text5 |
| --- | --- | --- | --- | --- | --- | --- | --- | --- | --- | --- | --- | --- | --- | --- | --- | --- | --- | --- | --- | --- | --- | --- | --- |
| 1 | 1 | Work Plan Rel-6 and after- VERSION 2003 April 25th | 1d | 2000-01-03 | 2000-01-03 |  |  | 2000-01-03 | 2000-01-03 | 1d | 1129d |  |  |  |  | Rel | 2044 |  |  |  |  |  |  |
| 2 | 2 | "CTRL + a" to display all the 3GPP fields | 1d | 2000-01-03 | 2000-01-03 |  |  | 2000-01-03 | 2000-01-03 | 1d | 1129d |  |  |  |  |  | 1462 |  |  |  |  |  |  |
| 3 | 3 | Content of Rel-6 and after. Not frozen. | 1d | 2000-01-03 | 2000-01-03 |  |  | 2000-01-03 | 2000-01-03 | 1d | 1129d |  |  |  |  | Rel | 2058 |  |  |  |  |  |  |
| 6 | 6 | Evolutions of the transport in the UTRAN | 895d | 2000-07-10 | 2003-12-12 |  |  | 2000-07-17 | 2002-03-29 | 445d | 95d | finish no earlier than 2003-12-12 | RP | 7160h |  | NA |  | ETRAN | Francois Courau | TSG | Joern |  |  |
| 7 | 8 | **Improvements of Radio Interface** | 935d? | 2000-08-14 A | 2004-03-12 | 39% | 569.07d? | 2000-06-19 | 2004-03-12 | 975d? | 30d |  | RP | 55040h | 24477h | NA |  | RInImp |  | TSG | Tsukasa |  |  |
| 8 | 8.1 | Improvement of inter-frequency and inter-system measurement | 705d | 2001-01-01 A | 2003-09-12 | 5% | 669.75d | 2001-01-01 | 2003-06-06 | 635d | 160d | finish no earlier than 2003-09-12 | R1 | 5640h | 282h | Rel-6 | 1470 | RInImp-IfIsM | Nokia (Antti Toskala) | TSG |  | BaAS |  |
| 9 | 8.2 | **Base station classification** | 603d | 2000-08-14 A | 2002-12-04 A | 100% |  | 2000-08-14 | 2002-12-04 | 603d |  |  | R4 | 9648h | 9648h | Rel-6 |  | RInImp-BSClass |  | TSG |  |  |  |
| 10 | 8.2.1 | FDD Base station classification | 603d | 2000-08-14 A | 2002-12-04 A | 100% |  | 2000-08-14 | 2002-12-04 | 603d |  | finish no earlier than 2002-12-04 | R4 | 4824h | 4824h | Rel-6 | 1476 | RInImp-BSClass-FDD | A. Toskala, Nokia | TSG |  | BaAs |  |
| 11 | 5.3 | UMTS-850 | 331d? | 2002-12-06 A | 2004-03-12 | 10% | 297.9d? | 2002-12-06 | 2004-03-12 | 331d? | 30d | finish no earlier than 2004-03-12 | R4 | 2648h | 264.8h |  |  | RInImp-UMTS850 | Don Zelmer, Cingular | TSG |  |  | don.zelmer@cingular.com |
| 12 | 5.4 | DS-CDMA introduction in the 800 MHz band | 136d? | 2003-03-14 | 2003-09-19 |  |  |  |  |  | 155d | finish no earlier than 2003-09-19 | R4 | 1088h |  | Rel-6 |  | RInImp-UMTS800 | Takehiro Nakamura, NTT DoCoMo | TSG |  |  | takehiro@wsp.yrp.nttdocomo.co.jp |
| 13 | 5.5 | UMTS 1.7/2.1 GHz | 196d? | 2003-03-14 | 2003-12-12 |  |  |  |  |  | 95d | finish no earlier than 2003-12-12 | R4 | 1568h |  | Rel-6 |  | RInImp-UMTS1721 | Jussi Numminen, Nokia | TSG |  |  | jussi.numminen@NOKIA.COM |
| 14 | 8.7 | FS for the viable deployment of UTRA in additional and diverse spectrum arrangements | 131d | 2002-03-08 A | 2002-09-06 | 90% | 13.1d | 2001-09-21 | 2003-03-14 | 386d | 425d |  | R4 | 1048h | 943.2h | Rel-6 |  | RInImp-UMTSBands | Thomas Unshelm, Ericsson | TSG | Cesar |  | Thomas.Unshelm@era.ericsson.se |
| 15 | 8.8 | FS on UE antenna efficiency test methods performance requirements (2) | 131d | 2002-03-08 A | 2002-09-06 A | 100% |  | 2002-03-08 | 2002-09-06 | 131d |  | finish no earlier than 2002-09-06 | R4 | 1048h | 1048h | Rel-6 |  | RInImp-UEAnTM2 | Alf Ahlström, Allgon | TSG |  |  |  |
| 16 | 8.10 | FS on Radio link performance enhancements | 810d | 2000-08-14 A | 2003-09-19 | 40% | 486d | 2000-08-14 | 2003-09-19 | 810d | 155d | finish no earlier than 2003-09-19 | R1 | 6480h | 2592h | Rel-6 | 1506 | RInImp-Rlperf | Antti Toskala, Nokia Networks | TSG |  |  |  |
| 17 | 8.11 | FS on UTRA WideBand Distribution Systems | 660d | 2001-03-12 A | 2003-09-19 | 40% | 396d | 2001-03-12 | 2003-03-14 | 525d | 155d | finish no earlier than 2003-09-19 | R4 | 5280h | 2112h | Rel-6 |  | RInImp-WDS | Andrea Casini, Tekmar Sistemi | TSG |  |  |  |
| 18 | 8.12 | FS on Improvement of inter-frequency and inter-system measurements for 1.28 Mcps TDD | 461d | 2001-12-14 A | 2003-09-19 | 55% | 207.45d | 2001-12-14 | 2003-03-14 | 326d | 155d | finish no earlier than 2003-09-19 | R1 | 3688h | 2028.4h | Rel-6 |  | RInImp-IfIsMLCR | Li Xiao Qiang, SAMSUNG | TSG |  |  |  |
| 19 | 8.13 | FS for the analysis of OFDM for UTRAN enhancements | 390d | 2002-06-10 A | 2003-12-05 | 30% | 273d | 2002-06-10 | 2003-06-13 | 265d | 100d | finish no earlier than 2003-12-05 | R1 | 3120h | 936h | Rel-6 |  | RInImp-FSOFDM | Sarah Boumendil, Nortel | TSG |  |  |  |
| 20 | 8.14 | FS on Uplink Enhancements for Dedicated Transport Channels | 326d | 2002-09-06 A | 2003-12-05 | 35% | 211.9d | 2002-09-06 | 2003-06-13 | 201d | 100d | finish no earlier than 2003-12-05 | R1 | 2608h | 912.8h | Rel-6 |  | RInImp-FSUpDTrCh | Karri Ranta-aho, Nokia | TSG |  |  |  |
| 21 | 8.15 | FS on Analysis on Higher Chip Rates for UTRA TDD evolutions | 326d | 2002-09-06 A | 2003-12-05 | 30% | 228.2d | 2002-09-06 | 2003-06-13 | 201d | 100d | finish no earlier than 2003-12-05 | R1 | 2608h | 782.4h | Rel-6 |  | RInImp-FSVHCRTDD | Tim Wilkinson, IPWireless | TSG |  |  |  |
| 22 | 5.14 | FS on Low Output Powers for general purpose FDD BSs | 136d? | 2003-03-14 | 2003-09-19 |  |  |  |  |  | 155d | finish no earlier than 2003-09-19 | R4 | 1088h |  | Rel-6 |  | RInImp-FSLOP | Jose Alberto Martin, Telefonica | TSG |  |  | martin_ja4@tsm.es |
| 23 | 8.5 | **Multiple Input Multiple Output antennas (MIMO)** | 531d? | 2002-03-08 A | 2004-03-19 | 31% | 365.48d? | 2001-03-16 | 2003-09-19 | 656d | 25d |  | R1 | 12848h | 4780h | Rel-6 | 2468 | RInImp-MIMO | Howard Huang, Lucent | TSG |  |  | hchuang@lucent.com |
| 24 | 6.1 | Multiple Input Multiple Output antennas - Physical layer | 136d? | 2003-03-14 A | 2003-09-19 | 40% | 81.6d? |  |  |  | 155d | finish no earlier than 2003-09-19 | R1 | 1088h | 435.2h | Rel-6 |  | RInImp-MIMO-Phys | Howard Huang, Lucent | TSG |  |  | hchuang@lucent.com |
| 25 | 6.2 | Multiple Input Multiple Output antennas - Layer 2,3 aspects | 136d? | 2003-03-14 | 2003-09-19 |  |  |  |  |  | 155d | finish no earlier than 2003-09-19 | R2 | 1088h |  | Rel-6 |  | RInImp-MIMO-L23 | Howard Huang, Lucent | TSG |  |  | hchuang@lucent.com |
| 26 | 6.3 | Multiple Input Multiple Output antennas - Iub/Iur Protocol Aspects | 136d? | 2003-03-14 | 2003-09-19 |  |  |  |  |  | 155d | finish no earlier than 2003-09-19 | R3 | 1088h |  | Rel-6 |  | RInImp-MIMO-IurIub | Howard Huang, Lucent | TSG |  |  | hchuang@lucent.com |
| 27 | 6.4 | Multiple Input Multiple Output antennas - RF Radio Transmission/Reception, System Performance Requirements and Conformance Testing | 266d? | 2003-03-14 | 2004-03-19 |  |  |  |  |  | 25d | finish no earlier than 2004-03-19 | R4 | 2128h |  | Rel-6 |  | RInImp-MIMO-RF | Howard Huang, Lucent | TSG |  |  | hchuang@lucent.com |
| 28 | 8.6 | Improving Receiver Performance Requirements for the FDD UE | 401d | 2002-03-08 A | 2003-09-19 | 70% | 120.3d | 2002-03-08 | 2003-09-19 | 401d | 155d | finish no earlier than 2003-09-19 | R4 | 3208h | 2245.6h | Rel-6 |  | RInImp-UERecPerf | Shimon Moshavi, Intel | TSG |  |  |  |

Notes:
- 6: To be deleted at TSG#18 if no input.
- 8: RP-020389
- 15: The RInImp-UEAnTM FS was re-opened at TSG RAN#15 upon request from WG4
- 16: RP-020358
- 18: RP-020374

| ID | WBS | Task | Duration | Start | Finish | Complete | Remaining | Baseline start | Baseline finish | Baseline duration | Total slack | Constraint | Resources | Work | Actual work | Text1 | Text6 | Text7 | Text8 | Text4 | Text2 | Text9 | Text5 | Text3 |
| --- | --- | --- | --- | --- | --- | --- | --- | --- | --- | --- | --- | --- | --- | --- | --- | --- | --- | --- | --- | --- | --- | --- | --- | --- |
| 29 | 9 | **RAN improvements** | 516d? | 2001-12-14 A | 2003-12-05 | 30% | 358.67d? | 2001-12-14 | 2003-06-30 | 402d? | 100d |  | RP | 19224h | 5367.46h | RANimp | NA | TSG | Cesar |  |  |  |  |  |
| 30 | 9.1 | Beamforming Enhancements | 386d | 2001-12-14 A | 2003-06-06 | 80% | 77.2d | 2001-12-14 | 2003-06-06 | 386d | 230d | finish no earlier than 2003-06-06 | R1 | 3088h | 2470.4h | RANimp-BFE | Rel-6 | TSG |  | Jussi Kähtävä, Nokia |  |  |  |  |
| 31 | 9.2 | **RAB support enhancement** | 136d? | 2003-03-14 | 2003-09-19 |  |  | 2002-09-16 | 2003-06-30 | 206d | 155d |  | R2 | 2176h |  | RANimp-RABSE | Rel-6 | TSG |  | M. Israelsson, A. Krishnarajah, Ericsson | BaAS | 624 |  |  |
| 32 | 7.2.1 | Iu enhancements for IMS support in RAN | 136d? | 2003-03-14 | 2003-09-19 |  |  |  |  |  | 155d | finish no earlier than 2003-09-19 | R3 | 1088h |  | RANimp-RABSE-IuEnhIMS | Rel-6 | TSG |  | Phillipe Godin, Nortel |  |  |  |  |
| 33 | 9.3 | Improvement of RRM across RNS and RNS/BSS | 445d | 2002-03-25 A | 2003-12-05 | 35% | 289.25d | 2002-03-25 | 2003-01-22 | 218d | 100d | finish no earlier than 2003-12-05 | R3 | 3560h | 1246h | RANimp-RRM1 | Rel-6 | TSG |  | Sami Kekki, Nokia |  |  | sami.kekki@nokia.com |  |
| 34 | 9.4 | FS on the evolution of the UTRAN architecture | 195d | 2002-09-09 A | 2003-06-06 | 5% | 185.25d | 2002-09-09 | 2003-06-13 | 200d | 230d | finish no earlier than 2003-06-06 | R3 | 1560h | 78h | RANimp-FSEvo | Rel-6 | TSG |  | Woonhee Hwang, Nokia |  |  |  |  |
| 35 | 7.5 | **Rel6 RRM optimization for Iur and Iub** | 131d? | 2002-12-06 A | 2003-06-06 | 15% | 111.35d? |  |  |  | 230d |  | R3 | 2096h | 314.4h | RANimp-RRMopt | Rel-6 | TSG |  | Gert-Jan van Lieshout, Ericsson | BaAS |  |  |  |
| 36 | 7.5.1 | FS of the improved access to UE measurement data for CRNC to support TDD RRM | 131d? | 2002-12-06 A | 2003-06-06 | 15% | 111.35d? | 2002-12-06 | 2003-06-06 | 131d? | 230d | finish no earlier than 2003-06-06 | R3 | 1048h | 157.2h | RANimp-RRMopt-FSTDDRRM | Rel-6 | TSG |  | Jim Miller, Interdigital |  |  |  |  |
| 37 | 7.6 | Remote Control of Electrical Tilting Antennas | 191d? | 2003-03-14 | 2003-12-05 |  |  |  |  |  | 100d | finish no earlier than 2003-12-05 | R3 | 1528h |  | RANimp-TiltAnt | Rel-6 | TSG |  | Andreas Hauser, Vodafone |  |  |  |  |
| 38 | 7.7 | Network Assisted Cell Change (NACC) from UTRAN to GERAN - network-side aspects | 136d? | 2003-03-14 | 2003-09-19 |  |  |  |  |  | 155d | finish no earlier than 2003-09-19 | R3 | 1088h |  | RANimp-NACC | Rel-6 | TSG |  | Brendan McWilliams, Vodafone |  |  | Brendan.McWilliams@gb.vodafone.co.uk |  |
| 39 | 8 | **PS domain and IMS impacts for supporting IMS Emergency calls** | 870d? | 2000-08-14 A | 2003-12-12 | 11% | 778.25d? |  |  |  | 95d |  | S2 | 30944h | 3117.37h | EMC1 | Rel-6 | TSG |  | Miikka Poikselka, Nokia |  |  |  |  |
| 40 | 10.1.1 | Service Requirements for IP-based emergency calls | 205d | 2000-09-18 A | 2001-06-29 | 44% | 115d | 2000-09-18 | 2001-06-29 | 205d | 740d | start no earlier than 2000-09-18 | S1 | 1640h | 720h |  |  |  |  |  | CCaR | 1314 |  | 22.976 |
| 41 | 8.2 | Stage 2 | 147d? | 2003-02-26 | 2003-09-18 |  |  |  |  |  | 161d | finish no earlier than 2003-09-18 | S2 | 1176h |  |  |  | TSG |  | Miikka Poikselka, Nokia |  |  |  |  |
| 42 | 10.1 | **Emergency Call Enhancements for IP& PS Based Calls – stage 3** | 870d | 2000-08-14 A | 2003-12-12 | 8% | 801.42d | 2000-09-18 | 2003-09-09 | 777d | 95d |  | N1 | 21368h | 1684.48h |  | Rel-6 |  |  | Mr Rouzbeh, Ericsson | CCaR | 1653 | EUSFARO@am1.ericsson.se |  |
| 43 | 10.1.2 | SIP emergency calls and packet emergency calls signalling flows | 824d | 2000-10-17 A | 2003-12-12 | 19% | 667.44d | 2000-10-17 | 2003-09-09 | 756d | 95d | finish no earlier than 2003-12-12 | N1 | 6592h | 1252.48h |  |  |  |  | Mr Rouzbeh, Ericsson | CCaR | 1315 | EUSFARO@am1.ericsson.se | TS 24.228 |
| 44 | 10.1.5 | Stage 3 for emergency calls and packet emergency calls in general | 870d | 2000-08-14 | 2003-12-12 |  |  | 2000-08-14 | 2003-09-09 | 802d | 95d | finish no earlier than 2003-12-12 | N1 | 6960h |  |  |  |  |  | Rouzbeh Farhoumand, Ericsson | CCaR | 1646 | rouzbeh.farhoumand@ericsson.com | TS 24.229 |
| 45 | 24.2 | Stage 3 for Emergency calls without UICC/SIM in netw. with IMS | 292d | 2002-07-29 | 2003-09-09 |  |  | 2002-07-29 | 2003-09-09 | 292d | 163d | finish no earlier than 2003-09-09 | N1 | 2336h |  | EMC-NOSIM |  |  |  |  |  |  |  |  |
| 46 | 12 | **Location Services enhancements 2** | 805d? | 2000-08-28 A | 2003-09-26 | 40% | 486.44d? | 2000-08-28 | 2003-11-21 | 845d? | 150d |  | S2 | 57032h | 21992.7h | LCS2 | Rel-6 | TSG | Alain |  |  |  |  |  |
| 47 | 12.1 | **Improvement on Le interface** | 331d? | 2002-06-17 A | 2003-09-22 | 59% | 135.71d? | 2002-06-21 | 2002-12-19 | 130d | 154d |  | S2 | 5296h | 3124.64h |  |  | TSG |  |  |  |  |  |  |
| 48 | 9.1.1 | Stage 2 | 331d? | 2002-06-17 A | 2003-09-22 | 59% | 135.71d? |  |  |  | 159d | start no earlier than 2002-06-17 | S2 | 2648h | 1562.32h |  |  |  |  |  |  |  |  |  |
| 49 | 12.2 | **Enhanced support for anonymity and user privacy** | 600d? | 2001-06-04 A | 2003-09-19 | 5% | 570d? | 2001-06-04 | 2002-12-20 | 405d | 155d |  | S2 | 9600h | 480h |  |  | TSG |  |  |  |  |  |  |
| 50 | 9.2.1 | Stage 2 | 600d? | 2001-06-04 A | 2003-09-19 | 5% | 570d? |  |  |  | 160d | start no earlier than 2001-06-04 | S2 | 4800h | 240h |  |  |  |  |  |  |  |  |  |
| 51 | 12.3 | **Enhanced inter-GMLC interface** | 320d? | 2002-06-24 A | 2003-09-12 | 56% | 140.8d? | 2002-06-24 | 2003-01-10 | 145d | 160d |  | S2 | 5120h | 2867.2h |  |  | TSG |  |  |  |  |  |  |
| 52 | 9.3.1 | Stage 2 | 320d? | 2002-06-24 A | 2003-09-12 | 56% | 140.8d? |  |  |  | 165d | start no earlier than 2002-06-24 | S2 | 2560h | 1433.6h |  |  |  |  |  |  |  |  |  |

Notes:
- 30: RP-020357
- 31: This is a building block without particular end date

| ID | WBS | Task | Duration | Start | Finish | Complete | Remaining | Baseline start | Baseline finish | Baseline duration | Total slack | Constraint | Resources | Work | Actual work | Text7 | Text1 | Text6 | Text4 | Text9 | Text8 | Text5 | Text2 | Text3 |
| --- | --- | --- | --- | --- | --- | --- | --- | --- | --- | --- | --- | --- | --- | --- | --- | --- | --- | --- | --- | --- | --- | --- | --- | --- |
| 53 | 12.4 | **Location Services support for IMS public identities** | 310d? | 2002-06-24 A | 2003-08-29 | 8% | 285.2d? | 2002-06-24 | 2002-10-25 | 90d | 170d |  | S2 | 4960h | 396.8h | TSG |  |  |  |  |  |  |  |  |
| 54 | 9.4.1 | Stage 2 | 310d? | 2002-06-24 A | 2003-08-29 | 8% | 285.2d? |  |  |  | 175d | start no earlier than 2002-06-24 | S2 | 2480h | 198.4h |  |  |  |  |  |  |  |  |  |
| 55 | 12.5 | **New area event for location service triggering reports** | 326d? | 2002-06-03 A | 2003-09-01 | 60% | 130.4d? | 2002-06-21 | 2002-12-20 | 131d | 169d |  | S2 | 5216h | 3129.6h | TSG |  |  |  |  |  |  |  |  |
| 56 | 9.5.1 | Stage 2 | 326d? | 2002-06-03 A | 2003-09-01 | 60% | 130.4d? |  |  |  | 174d | start no earlier than 2002-06-03 | S2 | 2608h | 1564.8h |  |  |  |  |  |  |  |  |  |
| 57 | 12.6 | FS on applicability of GALILEO for LCS | 270d | 2002-09-09 A | 2003-09-19 | 46% | 145d | 2002-09-16 | 2003-03-21 | 135d | 155d | start no earlier than 2002-09-09 | S2 | 2160h | 1000h |  |  |  |  |  |  |  |  |  |
| 58 | 12.7 | **UE positionning** | 805d? | 2000-08-28 A | 2003-09-26 | 46% | 436.62d? | 2000-08-28 | 2003-06-30 | 741d | 150d |  | RP | 19840h | 9079.14h | TSG | LCS2-UEpos | Rel-6 |  |  |  |  |  |  |
| 59 | 12.7.1 | UE positioning enhancements - other methods | 805d | 2000-08-28 A | 2003-09-26 | 10% | 723.49d | 2000-08-28 | 2003-06-30 | 741d | 150d | finish no earlier than 2003-06-30 | R2 | 6440h | 652.08h | TSG | LCS2-UEpos-enh |  | M. Beckmann, Siemens | 2457 |  |  |  |  |
| 60 | 12.7.2 | FS on Enhancements to OTDOA Positioning using advanced blanking methods | 245d | 2002-07-01 A | 2003-06-06 | 50% | 122.5d | 2002-07-01 | 2003-06-06 | 245d | 230d | finish no earlier than 2003-06-06 | R2 | 1960h | 980h | TSG | LCS2-UEpos-FSBlank |  | David Bartlett, Cambridge Positioning Systems |  |  |  |  |  |
| 61 | 12.8 | Open SMLC-SRNC Interface within the UTRAN to support UTRAN Rel4 positioning methods | 625d? | 2001-01-15 A | 2003-06-06 | 90% | 62.5d? | 2001-01-15 | 2003-03-14 | 565d? | 230d |  | R2 | 5000h | 4500h | TSG | LCS-Rel4Pos | Rel-6 | Meik Kottkamp, Siemens | 2475 |  |  |  |  |
| 62 | 10 | **Uplink TDOA location determination for GSM/GPRS** | 266d | 2002-11-15 A | 2003-11-21 | 9% | 240.93d | 2002-11-15 | 2003-11-21 | 266d | 110d |  | GP | 5544h | 522.59h | TSG | UTDOA | Rel-6 | Gross/Robinson, TruePosition, Inc. |  | Paolo |  |  |  |
| 63 | 10.1 | Addition of U-TDOA in the CS domain | 161d | 2002-11-15 A | 2003-06-27 | 25% | 120.75d | 2002-11-15 | 2003-06-27 | 161d | 215d | finish no earlier than 2003-06-27 | GP | 1288h | 322h |  | UTDOA-CS | Rel6 |  |  |  |  |  |  |
| 64 | 10.2 | Addition of U-TDOA in the PS domain | 266d | 2002-11-15 | 2003-11-21 |  |  | 2002-11-15 | 2003-11-21 | 266d | 110d | finish no earlier than 2003-11-21 | GP | 2128h |  |  | UTDOA-PS | Rel-6 |  |  |  |  |  |  |
| 65 | 14 | **Security enhancements** | 573d | 2001-01-03 A | 2003-03-14 | 27% | 417d | 2000-02-21 | 2003-09-19 | 935d | 290d |  | S3 | 15312h | 4992h | TSG | SEC1 | NA | Peter Howard, Vodafone |  | Maurice | Peter.Howard@vodafone.com |  |  |
| 66 | 14.1 | **Enhanced HE control of security (including positive authentication reporting)** | 573d | 2001-01-03 A | 2003-03-14 | 27% | 417d | 2001-01-03 | 2003-03-14 | 573d | 290d |  | S3 | 10728h | 3744h |  |  | Rel-6 | Peter Howard, Vodafone | 2026 |  | Peter.Howard@vodafone.com |  |  |
| 67 | 14.1.1 | Stage 2 | 378d | 2001-01-03 | 2002-06-14 |  |  | 2001-01-03 | 2002-06-14 | 378d | 490d | finish no earlier than 2002-06-14 | S3 | 3024h |  |  |  |  |  | 2027 |  |  |  |  |
| 68 | 14.1.3 | **Network domain security** | 195d | 2002-06-17 A | 2003-03-14 | 80% | 39d | 2002-06-17 | 2003-03-14 | 195d | 290d |  | S3 | 3120h | 2496h | TSG | SEC1-NDS | Rel-6 | Geir M. Køien, Telenor |  |  | Geir-myrdahl.koien@telenor.com | Sec |  |
| 69 | 14.1.3.1 | IP network layer security (NDS/IP) | 195d | 2002-06-17 A | 2003-03-14 | 80% | 39d | 2002-06-17 | 2003-03-14 | 195d | 295d | finish no earlier than 2003-03-14 | S3 | 1560h | 1248h | WG | SEC1-NDS-IP | Rel-6 |  |  |  |  |  | TS 33.210 |
| 70 | 16 | **IMS Phase 2** | 864d? | 2000-08-28 A | 2003-12-18 | 41% | 507.51d? | 2000-01-03 | 2003-12-18 | 1034d? | 91d |  | S1 | 103888h | 42526.7h | TSG | IMS2 | Rel-6 |  |  | Alain |  |  |  |
| 71 | 16.1 | Stage 2 of IMS Phase 2 | 205d | 2002-09-02 A | 2003-06-13 | 54% | 95d | 2002-09-02 | 2003-06-13 | 205d | 225d | finish no earlier than 2003-06-13 | S2 | 1640h | 880h |  |  |  |  |  |  |  |  |  |
| 72 | 16.2 | IMS Stage-3 Enhancements | 261d | 2002-09-20 A | 2003-09-19 | 2% | 255.78d | 2002-09-20 | 2003-09-19 | 261d | 155d | finish no earlier than 2003-09-19 | N1 | 2088h | 41.76h |  | IMS-CCR-E |  | Keith Drage, Lucent |  |  | drage@lucent.com |  |  |
| 73 | 16.12 | **IMS Group Management** | 457d? | 2002-03-14 A | 2003-12-12 | 27% | 334.73d? | 2002-03-14 | 2003-09-19 | 397d? | 95d |  | S1 | 7984h | 2136.2h | TSG | IMSGM |  | Juha Kalliokulju (Nokia) |  |  | juha.kalliokulju@nokia.com |  |  |
| 74 | 16.12.1 | Stage 1 - TS on IMS group management | 193d | 2002-03-14 A | 2002-12-09 | 75% | 48.25d | 2002-03-14 | 2002-12-09 | 193d | 359d | finish no earlier than 2002-12-09 | S1 | 1544h | 1158h | TSG |  |  | Juha Kalliokulju (Nokia) |  |  | juha.kalliokulju@nokia.com |  |  |
| 75 | 12.3.2 | Stage 2 | 87d? | 2003-02-27 | 2003-06-27 |  |  | 2003-02-27 | 2003-06-27 | 87d? | 215d | finish no earlier than 2003-06-27 | S2 | 696h |  |  |  |  |  |  |  |  |  |  |
| 76 | 12.3.3 | Stage 3 for IMS Group management (e.g. chat) | 261d? | 2002-12-13 | 2003-12-12 |  |  | 2002-09-20 | 2003-09-19 | 261d? | 95d | finish no earlier than 2003-12-12 | N1 | 2088h |  |  |  |  |  |  |  |  |  |  |

Notes:
- 59: This is a building block without particular end date
- 62: Ongoing
- 65: Added BB UE authentication and rapporteur added.
- 66: Added by P-000575 without any dates. 18/10/00: Change of WI title, added hyperlink rapporteur new end date 03/01. New end date and correct Release to be decided S3#18
- 67: New end date and correct Release to be decided S3#18
- 68: WID approved for Rel-6 at SA#17
- 69: Should be complete after SA3#27
- 70: Not yet available: verbally approved at SA15, actual WID to be provided at SA16 by Lucent

| ID | WBS | Task | Duration | Start | Finish | Complete | Remaining | Baseline start | Baseline finish | Baseline duration | Total slack | Constraint | Resources | Work | Actual work | Text1 | Text4 | Text5 | Text7 | Text3 | Text2 | Text9 |
| --- | --- | --- | --- | --- | --- | --- | --- | --- | --- | --- | --- | --- | --- | --- | --- | --- | --- | --- | --- | --- | --- | --- |
| 77 | 12.4 | **IMS Conferencing** | 290d? | 2002-11-04 A | 2003-12-12 | 19% | 236.17d? | 2002-09-20 | 2003-09-19 | 261d? | 95d |  | N1 | 5768h | 1070.62h |  |  |  |  |  |  |  |
| 78 | 12.4.1 | Stage 2 | 170d? | 2002-11-04 A | 2003-06-27 | 47% | 90d? | 2002-11-04 | 2003-06-27 | 170d? | 215d | finish no earlier than 2003-06-27 | S2 | 1360h | 640h |  |  |  |  |  |  |  |
| 79 | 12.4.2 | Stage 3 | 261d? | 2002-12-13 | 2003-12-12 |  |  | 2002-09-20 | 2003-09-19 | 261d? | 95d | finish no earlier than 2003-12-12 | N1 | 2088h |  |  |  |  |  |  |  |  |
| 80 | 12.5 | **PSS alignment to IMS** | 261d? | 2002-12-13 | 2003-12-12 |  |  | 2002-09-20 | 2003-09-19 | 261d? | 95d |  | N1 | 4184h |  |  |  |  |  |  |  |  |
| 81 | 12.5.1 | Stage 2 for PSS - CHECK AT SA2 | 1d? | 2003-01-06 | 2003-01-06 |  |  | 2003-01-06 | 2003-01-06 | 1d? | 339d | start no earlier than 2003-01-06 | S2 | 8h |  |  |  |  |  |  |  |  |
| 82 | 12.5.2 | Stage 3 | 261d? | 2002-12-13 | 2003-12-12 |  |  | 2002-09-20 | 2003-09-19 | 261d? | 95d | finish no earlier than 2003-12-12 | N1 | 2088h |  |  |  |  |  |  |  |  |
| 83 | 16.11 | **IMS Messaging** | 457d? | 2002-03-14 A | 2003-12-12 | 54% | 212.48d? | 2002-03-14 | 2003-09-19 | 397d? | 95d |  | S1 | 13040h | 7429.36h | IMSM | Juha Kalliokulju (Nokia) | juha.kalliokulju@nokia.com | TSG |  |  |  |
| 84 | 16.11.1 | TR on support of messaging in the IMS | 193d | 2002-03-14 A | 2002-12-09 A | 100% |  | 2002-03-14 | 2002-12-09 | 193d |  | finish no earlier than 2002-12-09 | S1 | 1544h | 1544h | IMSM-TR | Juha Kalliokulju (Nokia) | juha.kalliokulju@nokia.com | TSG |  |  |  |
| 85 | 12.6.2 | Stage 1 22.340 | 23d? | 2002-11-11 A | 2002-12-11 | 95% | 1.15d? | 2002-11-11 | 2002-12-11 | 23d? | 357d | finish no earlier than 2002-12-11 | S1 | 184h | 174.8h | IMSM-TS | Juha Kalliokulju (Nokia) | juha.kalliokulju@nokia.com | TSG | 22.340 |  |  |
| 86 | 16.11.2 | **CRs to existing 22-series specifications** | 263d? | 2002-03-14 A | 2003-03-17 | 75% | 65.75d? | 2002-03-14 | 2003-03-17 | 263d? | 289d |  | S1 | 4208h | 3156h | IMSM-CR | Juha Kalliokulju (Nokia) | juha.kalliokulju@nokia.com | TSG |  |  |  |
| 87 | 12.6.3.1 | CRs to 22.140 & 22.228 | 263d? | 2002-03-14 A | 2003-03-17 | 75% | 65.75d? | 2002-03-14 | 2003-03-17 | 263d? | 289d | finish no earlier than 2003-03-17 | S1 | 2104h | 1578h | IMSM-CR | Juha Kalliokulju (Nokia) | juha.kalliokulju@nokia.com | TSG | 22.140,22.228 |  |  |
| 88 | 16.11.3 | Stage 2 | 170d | 2002-11-04 A | 2003-06-27 | 44% | 95.2d | 2002-11-04 | 2003-06-27 | 170d | 215d | finish no earlier than 2003-06-27 | S2 | 1360h | 598.4h |  |  |  |  |  |  |  |
| 89 | 12.6.5 | Stage 3 for IMS Messaging | 261d? | 2002-12-13 | 2003-12-12 |  |  | 2002-09-20 | 2003-09-19 | 261d? | 95d | finish no earlier than 2003-12-12 | N1 | 2088h |  |  |  |  |  |  |  |  |
| 90 | 16.7 | **IMS Local services** | 710d? | 2001-01-01 A | 2003-09-19 | 55% | 316.23d? | 2001-01-01 | 2003-09-19 | 710d? | 155d |  | S2 | 10368h | 5192.02h |  |  |  |  | 23.228 |  |  |
| 91 | 16.7.1 | Stage 2 | 325d | 2001-01-01 A | 2002-03-29 A | 100% |  | 2001-01-01 | 2002-03-29 | 325d |  | start no earlier than 2001-01-01 | S2 | 2600h | 2600h |  |  |  |  |  |  |  |
| 92 | 12.7.2 | Stage 3 for IMS Local services | 261d? | 2002-09-20 | 2003-09-19 |  |  | 2002-09-20 | 2003-09-19 | 261d? | 155d | finish no earlier than 2003-09-19 | N1 | 2088h |  |  |  |  |  |  |  |  |
| 93 | 12.8 | **Additional SIP Capabilities support not covered by Rel-5** | 285d? | 2002-11-11 A | 2003-12-12 | 18% | 234.82d? | 2002-09-20 | 2003-09-19 | 261d? | 95d |  | N1 | 5688h | 1001.41h |  |  |  |  |  |  |  |
| 94 | 12.8.1 | Stage 2 for add SIP cap (e.g. forking) | 165d? | 2002-11-11 A | 2003-06-27 | 45% | 90d? | 2002-11-11 | 2003-06-27 | 165d? | 215d | start no earlier than 2002-11-11 | S2 | 1320h | 600h |  |  |  |  |  |  |  |
| 95 | 12.8.2 | Stage 3 for Additional SIP Capabilities | 261d? | 2002-12-13 | 2003-12-12 |  |  | 2002-09-20 | 2003-09-19 | 261d? | 95d | finish no earlier than 2003-12-12 | N1 | 2088h |  |  |  |  |  |  |  |  |
| 96 | 12.9 | Review additional SIP Capabilities against IMS | 261d? | 2002-12-13 | 2003-12-12 |  |  | 2002-09-20 | 2003-09-19 | 261d? | 95d | finish no earlier than 2003-12-12 | N1 | 2088h |  |  |  |  |  |  |  |  |
| 97 | 16.5 | **Interworking between IMS and IP networks** | 675d | 2000-08-28 A | 2003-03-28 | 35% | 442.12d | 2000-08-28 | 2003-03-28 | 675d | 280d |  | N3 | 16200h | 5846h | IMS-CCR-IWIP | Nigel Holland, BT | nigel.holland@bt.com | TSG | 23.821, 29.061, 29.162 | BaAS | 2048 |
| 98 | 16.5.1 | Interworking for 3GPP_SIP and IETF_SIP | 675d | 2000-08-28 A | 2003-03-28 | 59% | 276.75d | 2000-08-28 | 2003-03-28 | 675d | 280d | finish no earlier than 2003-03-28 | N3 | 5400h | 3186h |  | Thomas Belling, Siemens |  |  | New TR 2x.abc |  |  |
| 99 | 16.5.2 | Interworking for IPv6 to IPv4 | 675d | 2000-08-28 A | 2003-03-28 | 10% | 607.5d | 2000-08-28 | 2003-03-28 | 675d | 280d | finish no earlier than 2003-03-28 | N3 | 5400h | 540h |  |  |  |  | 29.163 |  |  |
| 100 | 16.8 | **Mm interface (CSCF to external IP multimedia network)** | 389d | 2001-03-14 A | 2002-09-09 | 71% | 112.81d | 2001-03-14 | 2002-09-09 | 389d | 424d |  | N3 | 6224h | 2209.52h |  |  |  |  |  |  |  |
| 101 | 16.8.1 | CN1 part | 389d | 2001-03-14 A | 2002-09-09 | 71% | 112.81d | 2001-03-14 | 2002-09-09 | 389d | 424d | finish no earlier than 2002-09-09 | N1 | 3112h | 2209.52h |  |  |  |  |  |  |  |

Notes:
- 97: [DAB 14.02.02] - end date pushed back to March 2003
- 98: [DAB - 14.02.02] - Need for new TR underinvestigation by CN3
- 99: [DAB - 14.02.02] - Requirements still not clear from SA2

| ID | WBS | Task | Duration | Start | Finish | Complete | Remaining | Baseline start | Baseline finish | Baseline duration | Total slack | Constraint | Resources | Work | Actual work | Text1 | Text2 | Text3 | Text4 | Text5 | Text7 | Text9 | Text6 | Text8 |
| --- | --- | --- | --- | --- | --- | --- | --- | --- | --- | --- | --- | --- | --- | --- | --- | --- | --- | --- | --- | --- | --- | --- | --- | --- |
| 102 | 16.6 | **Interworking between IMS and CS networks** | 595d | 2000-08-28 A | 2002-12-06 | 60% | 238d | 2000-08-28 | 2002-12-06 | 595d | 360d |  | N3 | 11456h | 6873.6h | IMS-CCR-IWCS | CCaR | 29.163, 29.061, 24.228, and new CN4 specification | David Sanders, Vodafone | dave.sanders@vf.vodafone.co.uk | TSG | 1305 |  |  |
| 103 | 16.6.1 | ITU-T Q.1912.SIP (SIP to BICC / ISUP interworking) | 595d | 2000-08-28 A | 2002-12-06 | 60% | 238d | 2000-08-28 | 2002-12-06 | 595d | 360d | finish no earlier than 2002-12-06 | N3 | 4760h | 2856h |  |  |  |  |  |  |  |  |  |
| 104 | 16.6.2 | ITU-T dependency on Q.2150.3 (SCTP) | 595d | 2000-08-28 A | 2002-12-06 | 60% | 238d | 2000-08-28 | 2002-12-06 | 595d | 360d | finish no earlier than 2002-12-06 | N3 | 4760h | 2856h |  |  |  |  |  |  |  |  |  |
| 105 | 16.9 | **Mg interface (BGCF to MGCF - interworking with CS)** | 371d | 2001-04-09 A | 2002-09-09 A | 100% |  | 2001-04-09 | 2002-09-09 | 371d |  |  | N3 | 5936h | 5936h |  |  |  |  |  |  |  |  |  |
| 106 | 16.9.1 | Mg interface (BGCF to MGCF - interworking with CS) | 371d | 2001-04-09 A | 2002-09-09 A | 100% |  | 2001-04-09 | 2002-09-09 | 371d |  | finish no earlier than 2002-06-07 | N1 | 2968h | 2968h |  |  |  |  |  |  |  |  |  |
| 107 | 16.10 | Mn interface (IM-MGW to MGCF) enhancements | 335d | 2002-09-02 A | 2003-12-12 | 60% | 134d | 2002-09-02 | 2003-06-06 | 200d | 95d | finish no earlier than 2003-12-12 | N4 | 2680h | 1608h | IMS-CCR-Mn |  |  | Peter Schmitt, Siemens |  |  |  |  |  |
| 108 | 12.15 | Mp (MRFC - MRFP) interface protocol definitions | 310d? | 2002-10-07 A | 2003-12-12 | 10% | 279d? | 2002-10-07 | 2003-06-06 | 175d? | 95d | finish no earlier than 2003-12-12 | N4 | 2480h | 248h | IMS-CCR-Mp |  |  | David Sanders, Vodafone |  |  |  |  |  |
| 109 | 12.16 | Study of subscriber and operators relationship in IMS and related ISIM requirements for Rel 6” | 20d? | 2002-11-15 A | 2002-12-12 | 75% | 5d? | 2002-11-15 | 2002-12-12 | 20d? | 356d | finish no earlier than 2002-12-12 | S1 | 160h | 120h |  |  |  | Juha Kalliokulju (Nokia) | juha.kalliokulju@nokia.com |  |  |  |  |
| 110 | 12.17 | Lawful Interception in the 3GPP Rel-6 architecture | 269d? | 2002-12-09 A | 2003-12-18 | 10% | 242.1d? | 2002-12-09 | 2003-12-18 | 269d? | 91d | finish no earlier than 2003-12-18 | S3 | 2152h | 215.2h | SEC1-LI |  | 33.106, 33.107, 33.108 | Berthold Wilhelm | Berthold.Wilhelm@REGTP.DE | TSG |  |  |  |
| 111 | 12.18 | IMS Subscription and access scenarios | 130d? | 2002-12-16 A | 2003-06-13 | 58% | 55d? |  |  |  | 225d | start no earlier than 2002-12-16 | S1 | 1040h | 600h |  |  | 22.800 |  |  |  |  |  |  |
| 112 | 16.4 | Radio optimisation impacts on PS domain architecture | 465d | 2001-12-10 A | 2003-09-19 | 63% | 170d | 2001-12-10 | 2003-09-19 | 465d | 155d | finish no earlier than 2003-04-25 | S2 | 3720h | 2360h |  |  |  |  |  | TSG |  | Rel-6 | Alain |
| 113 | 16.3 | **Interoperability and Commonality between IMS using different "IP-connectivity Networks"** | 257d | 2002-09-16 A | 2003-09-09 | 28% | 184.56d | 2002-09-16 | 2003-09-09 | 257d | 163d |  | N1 | 5632h | 1587.54h | IMSCOOP |  |  | Keith Drage, Lucent | drage@lucent.com | TSG |  | Rel-6 | Alain |
| 114 | 16.3.1 | Stage 2 | 210d | 2002-09-16 A | 2003-07-04 | 60% | 84d | 2002-09-16 | 2003-07-04 | 210d | 210d | finish no earlier than 2003-02-20 | S2 | 1680h | 1008h |  |  |  | Balazs Beternyi, Nokia |  |  |  |  |  |
| 115 | 16.3.2 | Stage 3 | 237d | 2002-10-14 | 2003-09-09 |  |  | 2002-10-14 | 2003-09-09 | 237d | 163d | finish no earlier than 2003-09-09 | N1 | 1896h |  |  |  |  |  |  |  |  |  |  |
| 116 | 17 | **Support of Push Services** | 778d | 2001-01-03 A | 2003-12-26 | 71% | 222.98d | 2001-01-03 | 2003-09-19 | 708d | 85d |  | S1 | 12094.6h | 4856.8h | PUSH | CCaR |  | Yoshinori Kitada, NTT Comware |  | TSG | 1365 | Rel-6 | Alain |
| 117 | 17.1 | Stage 1 | 378d | 2001-01-03 A | 2002-06-14 | 95% | 18.9d | 2001-01-03 | 2002-06-14 | 378d | 485d | finish no earlier than 2002-06-14 | S1 | 3024h | 2872.8h |  |  |  |  |  |  |  |  |  |
| 118 | 17.2 | TR on feasibility study | 178d | 2001-01-03 A | 2001-09-07 A | 100% |  | 2001-01-03 | 2001-09-07 | 178d |  | finish no earlier than 2001-09-07 | S2 | 1424h | 1424h |  |  |  |  |  |  |  |  |  |
| 119 | 17.3 | Stage 2 | 295d | 2002-11-11 A | 2003-12-26 | 24% | 225d | 2002-11-11 | 2003-09-19 | 225d | 85d | finish no earlier than 2003-12-26 | S2 | 2360h | 560h |  |  |  | Nick Alfano, RIM |  |  |  |  |  |
| 120 | 18 | **Multimedia Messaging (MMS) enhancements** | 410d? | 2002-08-15 A | 2004-03-10 | 8% | 376.58d? | 2002-08-15 | 2003-06-13 | 217d? | 32d |  | T2 | 15632h | 1545.38h | MMS6 | Mes |  | Josef Laumen, Siemens | Josef.Laumen@SAL.SIEMENS.DE | TSG |  | Rel-6 | Friedhelm |
| 121 | 18.1 | **Definition of service requirements** | 286d? | 2002-11-15 A | 2003-12-20 | 20% | 228.8d? | 2002-11-15 | 2003-06-13 | 151d? | 90d |  | S1 | 4576h | 915.2h | MMS6-SR |  | 22.140 |  |  |  |  |  |  |
| 122 | 16.1.1 | Definition of service requirements charging | 286d? | 2002-11-15 A | 2003-12-20 | 20% | 228.8d? | 2002-11-15 | 2003-06-13 | 151d? | 90d | finish no earlier than 2003-12-20 | S1 | 2288h | 457.6h |  |  | 22.140 | Josef Laumen, Siemens | Josef.Laumen@SAL.SIEMENS.DE |  |  |  |  |
| 123 | 18.2 | Technical realization | 345d | 2002-08-15 A | 2003-12-10 | 10% | 310.5d | 2002-08-15 | 2003-06-13 | 217d | 97d | finish no earlier than 2003-12-10 | T2 | 2760h | 276h |  |  | 23.140 | Josef Laumen, Siemens | Josef.Laumen@SAL.SIEMENS.DE |  |  |  |  |
| 124 | 18.3 | OMA dependencies | 410d | 2002-08-15 | 2004-03-10 |  |  | 2002-08-15 | 2003-06-13 | 217d | 32d | finish no earlier than 2004-03-10 | T2 | 3280h |  |  |  |  |  |  |  |  |  |  |
| 125 | 18.4 | MMS formats and codecs | 217d | 2002-08-15 A | 2003-06-13 | 5% | 206.15d | 2002-08-15 | 2003-06-13 | 217d | 225d | finish no earlier than 2003-06-13 | S4 | 1736h | 86.8h |  |  | 26.140 |  |  |  |  |  |  |

Notes:
- 103: [DAB - 17.05.02] - estimated ITU delivery date pushed to Dec. 2002
- 104: [DAB - 17.05.02] - estimated ITU delivery date pushed to Dec. 2002
- 107: 17th May 2002, CN4; Will be handled in Rel-6 / 02/08/2002 CN4: WID approved at CN4#15 (N4-020997) / 01/09/2002 KK: WID approved at CN#17 (NP-020494) / 15/11/2002CN4: Target will be CN#20 (NP-020600) / 14/03/2003CN#19: Target will be CN#22 (NP-030115)
- 108: 27/11/2002 KK: WID approved at CN#18 (NP-020601) / 27/11/2002CN4: Target will be CN#20
- 116: AS: Changed from FS to actual support of Push
- 118: Stage 2 on hold, waiting for requirements.

| ID | WBS | Task | Duration | Start | Finish | Complete | Remaining | Baseline start | Baseline finish | Baseline duration | Total slack | Constraint | Resources | Work | Actual work | Text1 | Text2 | Text6 | Text7 | Text8 | Text3 | Text4 | Text5 | Text9 |
| --- | --- | --- | --- | --- | --- | --- | --- | --- | --- | --- | --- | --- | --- | --- | --- | --- | --- | --- | --- | --- | --- | --- | --- | --- |
| 126 | 19 | **Rel-6 MExE enhancements** | 326d | 2002-03-08 A | 2003-06-06 A | 100% |  | 2002-03-08 | 2003-06-13 | 331d |  |  | T2 | 7328h | 7328h | MEXE6 | Ter | Rel-6 | TSG | Friedhelm |  |  |  |  |
| 127 | 19.1 | MExE Rel-6 Improvements and Investigations | 264d | 2002-03-08 A | 2003-03-12 A | 100% |  | 2002-03-08 | 2003-06-13 | 331d |  | finish no earlier than 2003-03-12 | T2 | 2112h | 2112h | MEXE6-ENHANC | Ter |  | TSG |  | 22.057, 23.057 | Lars Brenk (TTPCom) | lsb_ttpcom@HOTMAIL.COM |  |
| 128 | 19.2 | MExE Run-Time Independent Framework Feasibility Study | 326d | 2002-03-08 A | 2003-06-06 A | 100% |  | 2002-03-08 | 2003-06-06 | 326d |  | finish no earlier than 2003-06-06 | T2 | 2608h | 2608h | MEXE6-RTIF | Ter |  | TSG |  | 22.857 | Aaron Cohen (Intel) | Aaron.Cohen@intel.com |  |
| 129 | 21 | Subscription Management | 715d | 2000-12-29 A | 2003-09-25 | 30% | 500.5d | 2000-12-29 | 2003-09-25 | 715d | 151d | finish no earlier than 2003-09-25 | S5 | 5720h | 1716h | SM |  | Rel-6 | TSG | Adrian | 32.140, 32.141 | Michael Eder (Nokia) | michael.eder@nokia.com |  |
| 130 | 22 | **Support of Presence Capability** | 715d | 2001-03-19 A | 2003-12-12 | 75% | 175.31d | 2001-03-19 | 2003-06-04 | 578d | 95d |  | S1 | 17528h | 13230.3h | PRESNC |  | Rel-6 | TSG | Michael |  | Mark Cataldo, Motorola |  | 11004 |
| 131 | 22.1 | Stage 1 | 610d | 2001-03-19 A | 2003-07-18 | 95% | 30.5d | 2001-03-19 | 2001-07-18 | 88d | 200d | finish no earlier than 2003-07-18 | S1 | 4880h | 4636h |  |  |  |  |  |  |  |  | 11005 |
| 132 | 22.2 | Stage 2 | 268d | 2001-09-12 A | 2002-09-20 A | 100% |  | 2001-09-12 | 2002-09-20 | 268d |  | finish no earlier than 2002-09-20 | S2 | 2144h | 2144h |  |  |  | TSG |  |  |  |  |  |
| 133 | 22.3 | Stage 3 | 440d | 2002-04-08 A | 2003-12-12 | 57% | 189.2d | 2002-04-08 | 2003-06-04 | 303d | 95d | finish no earlier than 2003-12-12 | N1 | 3520h | 2006.4h |  |  |  |  |  |  | Keith Drage, Lucent | drage@lucent.com |  |
| 134 | 22.4 | Security issues | 79d | 2002-08-26 A | 2002-12-12 | 20% | 63.2d | 2002-08-26 | 2002-12-12 | 79d | 356d | finish no earlier than 2002-12-12 | S3 | 632h | 126.4h |  |  |  |  |  |  |  |  |  |
| 135 | 22.5 | USIM issues | 79d | 2002-03-04 | 2002-06-20 |  |  | 2002-03-04 | 2002-06-20 | 79d | 481d | start no earlier than 2002-03-04 | T3 | 632h |  |  |  |  |  |  |  |  |  |  |
| 136 | 25 | **Enhanced A/Gb feasibility study** | 51d? | 2002-08-30 A | 2002-11-08 | 75% | 12.75d? | 2002-08-30 | 2002-11-08 | 51d? | 380d |  | GP | 4080h | 3162h | AGbEnFS |  | TBD | TSG | Paolo |  | J-L Carrizo, Vodafone | jose-luis.carrizo@vodafone.co.uk |  |
| 137 | 25.1 | **Feasibility study on A/Gb enhancements** | 51d? | 2002-08-30 A | 2002-11-08 | 75% | 12.75d? | 2002-08-30 | 2002-11-08 | 51d? | 380d |  | G2 | 3672h | 2856h | AGbEnFS-FS |  |  | TSG |  |  |  |  |  |
| 138 | 25.1.1 | Requirements for the support of conversational services | 51d | 2002-08-30 A | 2002-11-08 A | 100% |  | 2002-08-30 | 2002-11-08 | 51d |  | finish no earlier than 2002-11-08 | GP | 408h | 408h |  |  |  |  |  |  |  |  |  |
| 139 | 20.1.2 | Identification of the different building blocks for the provision of conversational services on the existing A/Gb protocol stack | 51d? | 2002-08-30 A | 2002-11-08 A | 100% |  | 2002-08-30 | 2002-11-08 | 51d? |  | finish no earlier than 2002-11-08 | GP | 408h | 408h |  |  |  |  |  |  |  |  |  |
| 140 | 20.1.3 | Outline of impact and feasibility of these building blocks and their different solutions | 51d? | 2002-08-30 A | 2002-11-08 A | 100% |  | 2002-08-30 | 2002-11-08 | 51d? |  | finish no earlier than 2002-11-08 | GP | 408h | 408h |  |  |  |  |  |  |  |  |  |
| 141 | 25.1.2 | Identification of the different building blocks for the provision of conversational services on the existing A/Gb protocol stack | 51d | 2002-08-30 | 2002-11-08 |  |  | 2002-08-30 | 2002-11-08 | 51d | 380d | finish no earlier than 2002-11-08 | G2 | 408h |  |  |  |  |  |  |  |  |  |  |
| 142 | 25.1.3 | Outline of impact and feasibility of these building blocks and their different solutions | 51d | 2002-08-30 | 2002-11-08 |  |  | 2002-08-30 | 2002-11-08 | 51d | 380d | finish no earlier than 2002-11-08 | G2 | 408h |  |  |  |  |  |  |  |  |  |  |
| 143 | 25.1.4 | Impact on 3GPP architecture and requirement to co-ordinatge with other TSGs (CN, SA) | 51d | 2002-08-30 A | 2002-11-08 A | 100% |  | 2002-08-30 | 2002-11-08 | 51d |  | finish no earlier than 2002-11-08 | GP | 408h | 408h |  |  |  |  |  |  |  |  |  |
| 144 | 25.1.5 | Standardisation effort | 51d | 2002-08-30 A | 2002-11-08 A | 100% |  | 2002-08-30 | 2002-11-08 | 51d |  | finish no earlier than 2002-11-08 | GP | 408h | 408h |  |  |  |  |  |  |  |  |  |
| 145 | 25.1.6 | Dependency to other features | 51d | 2002-08-30 A | 2002-11-08 A | 100% |  | 2002-08-30 | 2002-11-08 | 51d |  | finish no earlier than 2002-11-08 | GP | 408h | 408h |  |  |  |  |  |  |  |  |  |
| 146 | 26 | **Flexible Layer One for GERAN** | 1015d | 2000-01-03 A | 2003-11-21 | 30% | 711.22d | 2000-01-03 | 2003-06-27 | 910d? | 110d |  | GP | 65007h | 16711.8h | FLOGER |  | Rel-6 | TSG | Paolo |  | Benoist Sébire | benoist.sebire@nokia.com |  |
| 147 | 26.1 | **Realisation of a Flexible Layer One** | 910d | 2000-01-03 A | 2003-06-27 | 40% | 546d | 2000-01-03 | 2003-06-27 | 910d | 215d |  | GP | 29488h | 11795.2h | FLOGER-Real |  |  |  |  |  | Benoist Sébire | benoist.sebire@nokia.com |  |
| 148 | 26.1.1 | Technical Report | 311d | 2002-04-19 A | 2003-06-27 | 40% | 186.6d | 2002-04-19 | 2003-06-27 | 311d | 215d | finish no earlier than 2003-06-27 | GP | 2488h | 995.2h |  |  |  |  |  |  |  |  |  |
| 149 | 26.1.2 | Architecture in 45.001 and 43.051 | 311d | 2002-04-19 A | 2003-06-27 | 40% | 186.6d | 2002-04-19 | 2003-06-27 | 311d | 215d | finish no earlier than 2003-06-27 | G1 | 2488h | 995.2h |  |  |  |  |  |  |  |  |  |
| 150 | 26.1.3 | Multiplexing in 45.002 | 311d | 2002-04-19 A | 2003-06-27 | 40% | 186.6d | 2002-04-19 | 2003-06-27 | 311d | 215d | finish no earlier than 2003-06-27 | G1 | 2488h | 995.2h |  |  |  |  |  |  |  |  |  |
| 151 | 26.1.4 | Channel Coding in 45.003 | 311d | 2002-04-19 A | 2003-06-27 | 40% | 186.6d | 2002-04-19 | 2003-06-27 | 311d | 215d | finish no earlier than 2003-06-27 | G1 | 2488h | 995.2h |  |  |  |  |  |  |  |  |  |
| 152 | 26.1.5 | Performance Requirements in 45.005 | 910d | 2000-01-03 A | 2003-06-27 | 40% | 546d | 2000-01-03 | 2003-06-27 | 910d | 215d | finish no earlier than 2003-06-27 | G1 | 7280h | 2912h |  |  |  |  |  |  |  |  |  |
| 153 | 26.1.6 | Radio subsystem link control in 45.008 | 311d | 2002-04-19 A | 2003-06-27 | 40% | 186.6d | 2002-04-19 | 2003-06-27 | 311d | 215d | finish no earlier than 2003-06-27 | G1 | 2488h | 995.2h |  |  |  |  |  |  |  |  |  |
| 154 | 26.1.7 | Requirements in 44.004 | 311d | 2002-04-19 A | 2003-06-27 | 40% | 186.6d | 2002-04-19 | 2003-06-27 | 311d | 215d | finish no earlier than 2003-06-27 | G2 | 2488h | 995.2h |  |  |  |  |  |  |  |  |  |

Notes:
- 130: A Sultan merged "Presence Service Enhancements" (UID31028, PRES1) to this feature as no answer was provided on why Presence and Presence Encmts had same target completion date
- 134: LSs handled in SA3. WID approved SA#17 Contribution at S3#25 & following e-mail discussion.
- 136: Closed
- 146: Nokia, Ericsson, Siemens, Telia
- 147: Started

| ID | WBS | Task | Duration | Start | Finish | Complete | Remaining | Baseline start | Baseline finish | Baseline duration | Total slack | Constraint | Resources | Work | Actual work | Text1 | Text4 | Text5 | Text3 | Text6 | Text8 | Text7 | Text9 |
| --- | --- | --- | --- | --- | --- | --- | --- | --- | --- | --- | --- | --- | --- | --- | --- | --- | --- | --- | --- | --- | --- | --- | --- |
| 155 | 26.2 | **Signalling and protocol support for a Flexible Layer One** | 311d | 2002-04-19 A | 2003-06-27 | 30% | 217.7d | 2002-04-19 | 2003-06-27 | 311d | 215d |  | G2 | 7464h | 2239.2h | FLOGER-SigPro | Benoist Sébire | benoist.sebire@nokia.com |  |  |  |  |  |
| 156 | 26.2.1 | Modifications to RLC/MAC in 44.060 and 44.160 | 311d | 2002-04-19 A | 2003-06-27 | 30% | 217.7d | 2002-04-19 | 2003-06-27 | 311d | 215d | finish no earlier than 2003-06-27 | G2 | 2488h | 746.4h |  |  |  |  |  |  |  |  |
| 157 | 26.2.2 | Modifications to RRC in 44.118 and 44.018 | 311d | 2002-04-19 A | 2003-06-27 | 30% | 217.7d | 2002-04-19 | 2003-06-27 | 311d | 215d | finish no earlier than 2003-06-27 | G2 | 2488h | 746.4h |  |  |  |  |  |  |  |  |
| 158 | 26.3 | **Security for a Flexible Layer One** | 311d | 2002-04-19 A | 2003-06-27 | 5% | 295.45d | 2002-04-19 | 2003-04-11 | 256d | 215d |  | S3, G2 | 4943.04h | 247.15h | FLOGER-SecFLO | Benoist Sébire | benoist.sebire@nokia.com |  |  |  |  |  |
| 159 | 26.3.1 | Ciphering in 44.160,44.118, 44.060 and 44.018 | 311d | 2002-04-19 A | 2003-06-27 | 5% | 295.45d | 2002-04-19 | 2003-04-11 | 256d | 215d | finish no earlier than 2003-06-27 | S3, G2 | 2488h | 124.4h |  |  |  |  |  |  |  |  |
| 160 | 26.4 | **GERAN MS Conformance test for the Flexible Layer One** | 260.5d | 2002-11-22 | 2003-11-21 |  |  | 2002-11-22 | 2003-06-27 | 155.5d | 110d |  | G4; G5 | 8336h |  | FLOGER-Msconf | Benoist Sébire | benoist.sebire@nokia.com |  |  |  |  |  |
| 161 | 26.4.1 | MS Test in 51.010 | 260.5d | 2002-11-22 | 2003-11-21 |  |  | 2002-11-22 | 2003-06-27 | 155.5d | 110d | finish no earlier than 2003-11-21 | G4; G5 | 4168h |  |  |  |  |  |  |  |  |  |
| 162 | 26.5 | **GERAN BTS Conformance test for the Flexible Layer One** | 416d | 2002-04-19 | 2003-11-21 |  |  | 2002-04-19 | 2003-06-27 | 311d | 110d |  | G3 | 6656h |  | FLOGER-BTSconf | Benoist Sébire | benoist.sebire@nokia.com |  |  |  |  |  |
| 163 | 26.5.1 | BTS Test in 51.021 | 416d | 2002-04-19 | 2003-11-21 |  |  | 2002-04-19 | 2003-06-27 | 311d | 110d | finish no earlier than 2003-11-21 | G3 | 3328h |  |  |  |  |  |  |  |  |  |
| 164 | 27 | Uplink TDOA feasibility study | 151d | 2001-11-30 A | 2002-06-28 A | 100% |  | 2001-11-30 | 2002-06-28 | 151d |  | finish no earlier than 2002-06-28 | GP | 1208h | 1208h | TDOAF | Bob Gross, TruePosition, Inc. | rlgross@trueposition.com | 45.811 | Rel-6 | Paolo |  |  |
| 165 | 28 | **Multimedia Broadcast and Multicast Service** | 661d | 2001-05-11 A | 2003-11-21 | 19% | 533.39d | 2001-05-11 | 2003-09-19 | 616d | 110d |  | S1 | 50241.6h | 8943.64h | MBMS |  |  |  | Rel-6 | Michael | TSG |  |
| 166 | 28.1 | Stage 1 | 232d | 2001-05-11 A | 2002-04-01 | 99% | 2.32d | 2001-05-11 | 2002-04-01 | 232d | 539d | finish no earlier than 2002-04-01 | S1 | 1856h | 1837.44h |  |  |  | 22.146, 22.101 |  |  |  | 11003 |
| 167 | 28.2 | **Stage 2** | 520d | 2001-09-24 A | 2003-09-19 | 71% | 148.57d | 2001-09-24 | 2003-09-19 | 520d | 155d |  | S2 | 8360h | 4324.8h |  |  |  |  |  |  | TSG |  |
| 168 | 28.2.1 | TR on Architectural Study | 240d | 2001-09-24 A | 2002-08-23 A | 100% |  | 2001-09-24 | 2002-08-23 | 240d |  | finish no earlier than 2002-08-23 | S2 | 1920h | 1920h |  |  |  |  |  |  |  |  |
| 169 | 28.2.2 | Stage 2 Specification Work | 285d | 2002-08-19 A | 2003-09-19 | 47% | 150d | 2002-08-19 | 2003-09-19 | 285d | 155d | finish no earlier than 2003-06-06 | S2 | 2280h | 1080h |  |  |  |  |  |  |  |  |
| 170 | 28.3 | Introduction of MBMS in RAN | 449d | 2002-01-01 A | 2003-09-19 | 13% | 390.63d | 2002-01-01 | 2003-06-13 | 379d | 155d | finish no earlier than 2003-09-19 | R2 | 3592h | 466.96h | MBMS-RAN | Dimitris Koulakiotis, Nokia |  |  |  |  | TSG | 2481 |
| 171 | 28.4 | Support of the MBMS in CN protocols | 321d | 2002-06-18 A | 2003-09-09 | 2% | 314.58d | 2002-06-18 | 2003-09-09 | 321d | 163d | finish no earlier than 2003-09-09 | N1 | 2568h | 51.36h |  |  |  |  |  |  | TSG |  |
| 172 | 28.5 | Security Aspects of Multimedia Broadcast/Multicast Service (MBMS) | 175d | 2002-07-01 A | 2003-02-28 | 20% | 140d | 2002-07-01 | 2003-02-28 | 175d | 300d | finish no earlier than 2003-02-28 | S3 | 1400h | 280h | MBMS | Escott, Adrian, Hutchison 3G UK | adrian.escott@hutchison3g.com |  |  |  | TSG |  |
| 173 | 28.6 | **Support of MBMS in GERAN** | 321d | 2002-08-30 A | 2003-11-21 | 7% | 297.81d | 2002-08-30 | 2003-06-27 | 216d | 110d |  | GP | 27456h | 1983.08h | MBMS-GERAN |  |  |  | Rel-6 |  | TSG |  |
| 174 | 28.6.1 | Impact on the logical and physical channels | 321d | 2002-08-30 A | 2003-11-21 | 10% | 288.9d | 2002-08-30 | 2003-06-27 | 216d | 110d | finish no earlier than 2003-11-21 | GP | 2568h | 256.8h |  |  |  |  |  |  |  |  |
| 175 | 28.6.2 | Simultaneous support of MBMS services | 216d | 2002-08-30 | 2003-06-27 |  |  | 2002-08-30 | 2003-06-27 | 216d | 215d | finish no earlier than 2003-06-27 | G1 | 1728h |  |  |  |  |  |  |  |  |  |
| 176 | 28.6.3 | Simultaneous support of MBMS and non-MBMS services | 216d | 2002-08-30 | 2003-06-27 |  |  | 2002-08-30 | 2003-06-27 | 216d | 215d | finish no earlier than 2003-06-27 | G1 | 1728h |  |  |  |  |  |  |  |  |  |
| 177 | 28.6.4 | Re-synchronisation at cell change | 216d | 2002-08-30 | 2003-06-27 |  |  | 2002-08-30 | 2003-06-27 | 216d | 215d | finish no earlier than 2003-06-27 | G2 | 1728h |  |  |  |  |  |  |  |  |  |
| 178 | 28.6.5 | Decision making process between point-to-point or pont-to-multipoint configurations | 321d | 2002-08-30 A | 2003-11-21 | 10% | 288.9d | 2002-08-30 | 2003-06-27 | 216d | 110d | finish no earlier than 2003-11-21 | GP | 2568h | 256.8h |  |  |  |  |  |  |  |  |
| 179 | 28.6.6 | MBMS channel allocations procedures to multiple MSs | 321d | 2002-08-30 A | 2003-11-21 | 10% | 288.9d | 2002-08-30 | 2003-06-27 | 216d | 110d | finish no earlier than 2003-11-21 | GP | 2568h | 256.8h |  |  |  |  |  |  |  |  |
| 180 | 28.6.7 | Changes to the Gb interface | 321d | 2002-08-30 A | 2003-11-21 | 10% | 288.9d | 2002-08-30 | 2003-06-27 | 216d | 110d | finish no earlier than 2003-11-21 | GP | 2568h | 256.8h |  |  |  |  |  |  |  |  |
| 181 | 28.6.8 | GERAN specific changes to the Iu-ps interface | 321d | 2002-08-30 A | 2003-11-21 | 10% | 288.9d | 2002-08-30 | 2003-06-27 | 216d | 110d | finish no earlier than 2003-11-21 | GP | 2568h | 256.8h |  |  |  |  |  |  |  |  |
| 182 | 28.6.9 | Interaction between MBMS and Iu-flex | 321d | 2002-08-30 A | 2003-11-21 | 10% | 288.9d | 2002-08-30 | 2003-06-27 | 216d | 110d | finish no earlier than 2003-11-21 | GP | 2568h | 256.8h |  |  |  |  |  |  |  |  |
| 183 | 28.6.10 | Security aspects | 321d | 2002-08-30 A | 2003-11-21 | 10% | 288.9d | 2002-08-30 | 2003-06-27 | 216d | 110d | finish no earlier than 2003-11-21 | GP | 2568h | 256.8h |  |  |  |  |  |  |  |  |
| 184 | 28.6.11 | MS conformance tests | 216d | 2002-08-30 | 2003-06-27 |  |  | 2002-08-30 | 2003-06-27 | 216d | 215d | finish no earlier than 2003-06-27 | G5 | 1728h |  |  |  |  |  |  |  |  |  |

Notes:
- 155: Started
- 158: Started
- 160: Not started
- 162: Not started
- 165: Title renamed at SA#13
- 166: This may or may not be a separate stage 1. In the meantime, CRs are proposed for 22.101
- 172: WID approved SA#17

| ID | WBS | Task | Duration | Start | Finish | Complete | Remaining | Baseline start | Baseline finish | Baseline duration | Total slack | Constraint | Resources | Work | Actual work | Text1 | Text6 | Text7 | Text8 | Text3 | Text4 | Text5 |
| --- | --- | --- | --- | --- | --- | --- | --- | --- | --- | --- | --- | --- | --- | --- | --- | --- | --- | --- | --- | --- | --- | --- |
| 185 | 29 | **Speech Recognition and Speech Enabled Services** | 975d? | 2000-01-03 A | 2003-09-26 | 21% | 769.48d? | 2000-01-03 | 2003-09-23 | 972d? | 150d |  | S1 | 9720h | 2048.84h | SRSES | Rel-6 | TSG | Michael |  |  |  |
| 186 | 24.1 | Why Stage 1 work on DSR, Stage 2 does not work and SA4 runs a codec competition? | 1d? | 2000-01-03 | 2000-01-03 |  |  | 2000-01-03 | 2000-01-03 | 1d? | 1124d |  | S2 | 8h |  |  |  |  |  |  |  |  |
| 187 | 29.1 | Speech Enabled Services Based on Distributed Speech Recognition (DSR) | 115d | 2001-10-08 A | 2002-03-15 | 85% | 17.25d | 2001-10-08 | 2002-03-15 | 115d | 550d | finish no earlier than 2002-03-15 | S1 | 920h | 782h | DSR |  | TSG |  | 22.941, 23.207, 22.243 | D Williams, QUALCOMM, Inc. | Dwilliams@qualcomm.com |
| 188 | 29.2 | Stage 2 | 152d | 2003-02-24 | 2003-09-23 |  |  | 2003-02-24 | 2003-09-23 | 152d | 153d | start no earlier than 2003-02-24 | S2 | 1216h |  |  |  |  |  |  |  |  |
| 189 | 29.3 | SES codec negotiation at SDP | 183d | 2002-09-23 | 2003-06-04 |  |  | 2002-09-23 | 2003-06-04 | 183d | 232d | finish no earlier than 2003-06-04 | N1 | 1464h |  |  |  |  |  |  |  |  |
| 190 | 24.5 | Codec Work to Support Speech Recognition Framework for Automated Voice Services | 249d? | 2002-10-15 A | 2003-09-26 | 20% | 199.2d? | 2002-10-15 | 2003-06-13 | 174d? | 150d | finish no earlier than 2003-09-26 | S4 | 1992h | 398.4h | SRSES-Codec |  | WG |  | 22.243 | David Pearce, Motorola |  |
| 191 | 30 | **Generic User Profile** | 570d | 2001-10-08 A | 2003-12-12 | 34% | 374.77d | 2001-10-08 | 2003-06-10 | 437d | 95d |  | S1 | 23591.8h | 8080.2h | GUP | Rel-6 | TSG | Michael |  |  |  |
| 192 | 30.1 | Stage 1 - Requirements | 430d | 2001-10-08 A | 2003-05-30 | 88% | 50d | 2001-10-08 | 2002-12-09 | 306d | 235d | finish no earlier than 2002-12-09 | S1 | 3440h | 3040h |  |  |  |  | 22.240, 22.228 | Paul Amery (Orange) | paul.amery@orange.co.uk |
| 193 | 30.2 | Stage 2 - Data Description Method | 568d | 2001-10-08 A | 2003-12-10 | 20% | 454.4d | 2001-10-08 | 2003-03-11 | 372d | 97d | finish no earlier than 2003-12-10 | T2 | 4544h | 908.8h |  |  | WG |  | 23.241 | HOLOUBEK, Kevin J. (Motorola) | kevin.holoubek@motorola.com |
| 194 | 30.3 | Stage 2 - Architecture | 355d | 2002-01-28 A | 2003-06-06 | 77% | 80d | 2002-01-28 | 2003-06-06 | 355d | 230d | finish no earlier than 2003-06-06 | S2 | 2840h | 2200h |  |  |  |  | 23.240 | Nacho Uzquiano (Telefonica) | uzquiano_ji@tsm.es |
| 195 | 30.4 | Stage 3 - Common objects | 568d | 2001-10-08 | 2003-12-10 |  |  | 2001-10-08 | 2003-06-10 | 437d | 97d | finish no earlier than 2003-12-10 | T2 | 4544h |  |  |  | WG |  | 24.241 | HOLOUBEK, Kevin J. (Motorola) | kevin.holoubek@motorola.com |
| 196 | 30.5 | Stage 3 - Network | 149.98d | 2003-05-19 | 2003-12-12 |  |  | 2002-11-18 | 2003-06-10 | 146.98d | 95d | finish no earlier than 2003-12-12 | N4 | 1199.84h |  |  |  |  |  | 29.240 |  |  |
| 197 | 30.6 | Security Aspects | 308d | 2002-07-16 A | 2003-09-18 | 15% | 261.8d | 2002-07-16 | 2003-05-09 | 214d | 156d | finish no earlier than 2003-09-18 | S3 | 2464h | 369.6h |  |  | WG |  | 33.102, 33.203, 33.210 | Owen, Bradley | bvowen@lucent.com |
| 198 | 31 | **Digital Rights Management** | 380d? | 2001-10-08 A | 2003-03-21 | 35% | 248.43d? | 2001-10-08 | 2003-03-21 | 380d? | 285d |  | S1 | 8688h | 3008.19h | DRM | Rel-6 | TSG | Michael |  |  |  |
| 199 | 31.1 | Requirements | 179d | 2001-10-08 A | 2002-06-13 | 95% | 8.95d | 2001-10-08 | 2002-06-13 | 179d | 486d | finish no earlier than 2002-06-13 | S1 | 1432h | 1360.4h |  |  |  |  |  | Nicholas Wood, Openwave Systems | nicholas.wood@openwave.com |
| 200 | 26.2 | Monitoring of Stages 2 and 3 progress (actual work to be done by OMA) | 155d? | 2002-08-19 | 2003-03-21 |  |  | 2002-08-19 | 2003-03-21 | 155d? | 285d | start no earlier than 2002-08-19 | S1 | 1240h |  |  |  |  |  |  |  |  |
| 201 | 31.3 | Security | 186d | 2002-06-17 A | 2003-03-03 | 40% | 111.6d | 2002-06-17 | 2003-03-03 | 186d | 299d | finish no earlier than 2003-03-03 | S3 | 1488h | 595.2h |  |  |  |  |  |  |  |
| 202 | 31.4 | Codec Aspects | 186d | 2002-06-17 | 2003-03-03 |  |  | 2002-06-17 | 2003-03-03 | 186d | 299d | finish no earlier than 2003-03-03 | S4 | 1488h |  |  |  |  |  |  |  |  |
| 203 | 32 | **FS on WLAN-UMTS Interworking** | 1030d? | 2000-01-03 A | 2003-12-12 | 68% | 329.38d? | 2000-01-03 | 2003-06-20 | 905d? | 95d |  | S1 | 27408h | 18643.4h | WLAN | Rel-6 | TSG | Michael |  | Fredric Paint, Telenor | frederic.paint@telenor.com |
| 204 | 32.1 | Technical Report | 900d? | 2000-01-03 A | 2003-06-13 | 95% | 45d? | 2000-01-03 | 2002-05-13 | 616d? | 225d | finish no earlier than 2003-06-13 | S1 | 7200h | 6840h | WLAN-TR |  |  |  | 22.934, 22.101, 22.105 | Fredric Paint, Telenor | frederic.paint@telenor.com |
| 205 | 27.2 | CRs to implement WLAN | 900d? | 2000-01-03 A | 2003-06-13 | 55% | 405d? | 2000-01-03 | 2002-05-13 | 616d? | 225d | finish no earlier than 2003-06-13 | S1 | 7200h | 3960h | WLAN-CR |  |  |  | 22.934, 22.101, 22.105, 22.115 | Fredric Paint, Telenor | frederic.paint@telenor.com |
| 206 | 32.2 | WLAN Interworking – Architecture Definition | 325d | 2002-03-25 A | 2003-06-20 | 72% | 90d | 2002-03-25 | 2003-06-20 | 325d | 220d | finish no earlier than 2003-03-21 | S2 | 2600h | 1880h |  |  | TSG |  |  |  |  |
| 207 | 32.3 | Security | 125d | 2002-09-30 A | 2003-03-21 | 30% | 87.5d | 2002-09-30 | 2003-03-21 | 125d | 285d | finish no earlier than 2003-03-21 | S3 | 1000h | 300h |  |  | TSG |  | 21.133, 33.106, 33.107, 33.108, 33.200, 33.203, 33.210 | Lopez-Soria, Luis, Ericsson | luis.lopez-soria@ece.ericsson.se |
| 208 | 27.5 | WLAN Interworking – stage 3 definition of WLAN – 3GPP interworking | 146d? | 2003-05-23 A | 2003-12-12 | 5% | 138.7d? |  |  |  | 95d | finish no earlier than 2003-12-12 | N4 | 1168h | 58.4h | WLAN-IW |  | TSG |  | 29.234, 29.061 | Rodriguez ,Raquel, Nokia | raquel.rodriguez@nokia.com |

Notes:
- 189: renamed according to Hannu's indication
- 196: 17 May no activity in CN4 / 02/08/2002 CN4: No activity in CN4 / 12/03/2003CN#19: CN4 have agreed in principle to undertake this work, but there was no substantive input (WID or technical). There is concern over the immaturity of the stage 1 & stage 2 specifications; we believe that we will need 6 months from when the stage 2 specification is stable in order to do the stage 3 work.
- 197: WID approved SA#17. SA WG3 progress slow, depends on progress in other groups.
- 198: Foreseen start and completion dates introduced by MCC (no indication at all on the WID)
- 201: SA3 acknowledge role in WI at SA3#20. Active contribution S3#24, S3#25. S3 WID approved SA#17
- 207: Active contribution S3#24, S3#25. WID approved SA#17
- 208: WID approved at CN#19

| ID | WBS | Task | Duration | Start | Finish | Complete | Remaining | Baseline start | Baseline finish | Baseline duration | Total slack | Constraint | Resources | Work | Actual work | Text1 | Text6 | Text7 | Text8 | Text3 | Text4 | Text5 |
| --- | --- | --- | --- | --- | --- | --- | --- | --- | --- | --- | --- | --- | --- | --- | --- | --- | --- | --- | --- | --- | --- | --- |
| 209 | 33 | **Priority Service** | 347d? | 2002-05-30 A | 2003-09-26 | 49% | 176.17d? | 2002-05-30 | 2003-03-17 | 208d | 150d |  | S1 | 5408h | 2662.32h | PRIOR | Rel-6 | TSG | Michael |  |  |  |
| 210 | 33.1 | Feasibility Study | 1d | 2002-06-14 A | 2002-06-14 | 98% | 0.02d | 2002-06-14 | 2002-06-14 | 1d | 485d | finish no earlier than 2002-06-14 | S1 | 8h | 7.84h | PRIOR-FS |  |  | Michael | 22.950 | Biplab K. Pramanik, Telcordia Technologies | bpramani@telcordia.com |
| 211 | 33.2 | Stage 1 - Requirements | 208d | 2002-05-30 A | 2003-03-17 | 80% | 41.6d | 2002-05-30 | 2003-03-17 | 208d | 289d | finish no earlier than 2003-03-17 | S1 | 1664h | 1331.2h | PRIOR-SR |  |  | Michael |  | James J. Garrahan, Telcordia Technologies | bpramani@telcordia.com |
| 212 | 28.3 | Priority Multimedia Service | 131d? | 2003-03-28 | 2003-09-26 |  |  |  |  |  | 150d | finish no earlier than 2003-09-26 | S1 | 1048h |  |  |  |  |  |  |  |  |
| 213 | 34 | **Network Sharing** | 240d? | 2003-01-20 A | 2003-12-19 | 45% | 131.6d? | 2001-11-14 | 2002-06-14 | 153d | 90d |  | S1 | 6912h | 3121.99h | NTShar | Rel-6 | TSG | Michael |  |  |  |
| 214 | 34.1 | Technical Report | 240d? | 2003-01-20 A | 2003-12-19 | 48% | 125.25d? | 2001-11-14 | 2002-06-14 | 153d | 90d |  | S1 | 1920h | 918h | NTShar-TR |  |  | Michael | 22.951 |  |  |
| 215 | 29.2 | Stage 1 - CRs to implement Network Sharing | 240d? | 2003-01-20 A | 2003-12-19 | 70% | 72d? |  |  |  | 90d | finish no earlier than 2003-12-19 | S1 | 1920h | 1344h | NTShar-CR |  |  |  | 22.011, 22.101, 22.115, 22.129 |  |  |
| 216 | 29.3 | Stage 2 | 146d? | 2003-02-27 | 2003-09-18 |  |  |  |  |  | 156d | finish no earlier than 2003-09-18 | S2 | 1168h |  |  |  |  |  |  |  |  |
| 217 | 35 | **QoS Improvements** | 245d | 2002-07-15 A | 2003-06-20 | 63% | 90d | 2002-07-15 | 2003-06-20 | 245d | 220d |  | S2 | 3920h | 2480h | QoS1 | NA | TSG | Alain |  |  |  |
| 218 | 35.1 | FS on Dynamic Policy control enhancements for end-to-end QoS | 245d | 2002-07-15 A | 2003-06-20 | 63% | 90d | 2002-07-15 | 2003-06-20 | 245d | 220d | finish no earlier than 2003-06-20 | S2 | 1960h | 1240h | QoS1 | Rel-6 | TSG |  |  |  | Claire Mousset, Nortel |
| 219 | 36 | **Support for subscriber certificates** | 189d | 2002-02-25 A | 2002-11-14 | 49% | 97.2d | 2002-02-25 | 2002-11-14 | 189d | 376d |  | S3 | 2856h | 1387.2h | SEC1-SC | Rel-6 | TSG | Maurice | 33.102 | Valtteri Niemi, Nokia | valtteri.niemi@nokia.com |
| 220 | 36.1 | Stage 1 | 144d | 2002-02-25 A | 2002-09-12 | 40% | 86.4d | 2002-02-25 | 2002-09-12 | 144d | 421d | finish no earlier than 2002-09-12 | S3 | 1152h | 460.8h |  |  |  |  |  |  |  |
| 221 | 36.2 | Architecture review | 24d | 2002-10-14 A | 2002-11-14 A | 100% |  | 2002-10-14 | 2002-11-14 | 24d |  | finish no earlier than 2002-11-14 | S2 | 192h | 192h |  |  |  |  |  |  |  |
| 222 | 38 | **Rel-6 OSA enhancements** | 899d? | 2000-07-11 A | 2003-12-19 | 34% | 589.35d? | 2000-07-11 | 2003-12-19 | 899d? | 90d |  | S1 | 57249.6h | 22094.6h | OSA3 | Rel-6 | TSG | Adrian | 22.127, 29.198, 29.998 | Chelo ABARCA (Alcatel) | Chelo.Abarca@alcatel.fr |
| 223 | 32.1 | Scope of the Open Service Access Release 6 | 66d? | 2003-03-28 | 2003-06-27 |  |  |  |  |  | 215d | finish no earlier than 2003-06-27 | S1 | 528h |  |  |  | TSG |  |  |  |  |
| 224 | 38.1 | Support of a Generic Network Interface Function (Stage 1) | 212.1d | 2002-02-27 A | 2003-01-06 A | 100% |  | 2002-02-27 | 2003-01-06 | 212.1d |  | finish no earlier than 2003-01-06 | S1 | 1696.79h | 1696.79h |  |  | TSG |  | 22.127 |  |  |
| 225 | 38.2 | Support of a Generic Network Interface Function (Stage 3) | 462d | 2002-02-14 A | 2003-12-19 | 15% | 392.7d | 2002-02-14 | 2003-12-19 | 462d | 90d | finish no earlier than 2003-12-19 | N5 | 3696h | 554.4h |  |  | TSG |  | 29.198, 29.998 |  |  |
| 226 | 38.11 | User Data Management / User data security management (Stage 1) | 212.1d | 2002-02-27 A | 2003-01-06 A | 100% |  | 2002-02-27 | 2003-01-06 | 212.1d |  | finish no earlier than 2003-01-06 | S1 | 1696.79h | 1696.79h |  |  | TSG |  | 22.127 |  |  |
| 227 | 38.12 | User Data Management / User data security management (Stage 3) | 462d | 2002-03-14 A | 2003-12-19 | 15% | 392.7d | 2002-03-14 | 2003-12-19 | 462d | 90d | finish no earlier than 2003-12-19 | N5 | 3696h | 554.4h |  |  | TSG |  | 29.198, 29.998 |  |  |
| 228 | 37.1.2 | Access to User Profile | 145d | 2001-06-01 A | 2001-12-20 | 90% | 14.5d | 2001-06-01 | 2001-12-20 | 145d | 611d | finish no earlier than 2001-12-20 | S1 | 1160h | 1044h | OSA1-UP |  | TSG |  |  |  |  |
| 229 | 32.7 | Retrieval of Visited Network capabilities | 297d? | 2002-10-31 A | 2003-12-19 | 15% | 252.45d? | 2002-10-31 | 2003-12-19 | 297d? | 90d | finish no earlier than 2003-12-19 | N5 | 2376h | 356.4h |  |  | TSG |  | 29.198, 29.998 |  |  |
| 230 | 32.8 | Access to IP Session information | 297d? | 2002-10-31 A | 2003-12-19 | 15% | 252.45d? | 2002-10-31 | 2003-12-19 | 297d? | 90d | finish no earlier than 2003-12-19 | N5 | 2376h | 356.4h |  |  | TSG |  | 29.198, 29.998 |  |  |
| 231 | 32.9 | Multi Media Messaging function | 297d? | 2002-10-31 A | 2003-12-19 | 15% | 252.45d? | 2002-10-31 | 2003-12-19 | 297d? | 90d | finish no earlier than 2003-12-19 | N5 | 2376h | 356.4h |  |  | TSG |  | 29.198, 29.998 |  |  |
| 232 | 32.10 | Enhanced user privacy in LCS | 297d? | 2002-10-31 A | 2003-12-19 | 15% | 252.45d? | 2002-10-31 | 2003-12-19 | 297d? | 90d | finish no earlier than 2003-12-19 | N5 | 2376h | 356.4h |  |  | TSG |  | 29.198, 29.998 |  |  |
| 233 | 32.11 | Policy management extensions | 297d? | 2002-10-31 A | 2003-12-19 | 15% | 252.45d? | 2002-10-31 | 2003-12-19 | 297d? | 90d | finish no earlier than 2003-12-19 | N5 | 2376h | 356.4h |  |  | TSG |  | 29.198, 29.998 |  |  |
| 234 | 32.12 | Presence and Availability Management (from the PRESNC WI) | 297d? | 2002-10-31 A | 2003-12-19 | 15% | 252.45d? | 2002-10-31 | 2003-12-19 | 297d? | 90d | finish no earlier than 2003-12-19 | N5 | 2376h | 356.4h |  |  | TSG |  | 29.198, 29.998 |  |  |
| 235 | 32.13 | Information Services | 297d? | 2002-10-31 A | 2003-12-19 | 15% | 252.45d? | 2002-10-31 | 2003-12-19 | 297d? | 90d | finish no earlier than 2003-12-19 | N5 | 2376h | 356.4h |  |  | TSG |  | 29.198, 29.998 |  |  |
| 236 | 32.14 | Information Transfer | 297d? | 2002-10-31 A | 2003-12-19 | 15% | 252.45d? | 2002-10-31 | 2003-12-19 | 297d? | 90d | finish no earlier than 2003-12-19 | N5 | 2376h | 356.4h |  |  | TSG |  | 29.198, 29.998 |  |  |
| 237 | 32.15 | OSA interfaces at different levels of abstractions (Parlay X, Web services) | 201d? | 2003-03-14 | 2003-12-19 |  |  |  |  |  | 90d | finish no earlier than 2003-12-19 | N5 | 1608h |  |  |  | TSG |  | 29.198, 29.998 |  |  |
| 238 | 32.16 | Introduction of migration support mechanism | 201d? | 2003-03-14 | 2003-12-19 |  |  |  |  |  | 90d | finish no earlier than 2003-12-19 | N5 | 1608h |  |  |  | TSG |  | 29.198, 29.998 |  |  |
| 239 | 32.17 | User Profile | 201d? | 2003-03-14 | 2003-12-19 |  |  |  |  |  | 90d | finish no earlier than 2003-12-19 | N5 | 1608h |  |  |  | TSG |  | 29.198, 29.998 |  |  |
| 240 | 32.18 | Network functions for end-user/application interaction support | 201d? | 2003-03-14 | 2003-12-19 |  |  |  |  |  | 90d | finish no earlier than 2003-12-19 | N5 | 1608h |  |  |  | TSG |  | 29.198, 29.998 |  |  |
| 241 | 32.19 | Framework Function for Federation | 201d? | 2003-03-14 | 2003-12-19 |  |  |  |  |  | 90d | finish no earlier than 2003-12-19 | N5 | 1608h |  |  |  | TSG |  | 29.198, 29.998 |  |  |
| 242 | 32.20 | Enhancements to IP Session Function in OSA for the control and monitor of IP Flows | 201d? | 2003-03-14 | 2003-12-19 |  |  |  |  |  | 90d | finish no earlier than 2003-12-19 | N5 | 1608h |  |  |  | WG |  | 29.198, 29.998 |  |  |
| 243 | 38.13 | Security | 202d | 2002-03-14 A | 2002-12-20 A | 100% |  | 2002-03-14 | 2002-12-20 | 202d |  | finish no earlier than 2002-12-20 | S3 | 1616h | 1616h |  |  | TSG |  |  |  |  |

Notes:
- 219: Approved at SA#14. This may require BBs from CN1, CN4, SA5 and T3
- 220: Contribution received S3#24, S3#25
- 222: TSG approval target 9/03->12/03. New Rapp. NP-030036 Rev WID replaces SP-020573.
- 237: Added New WT
- 238: Added New WT
- 239: Added New WT
- 240: Added New WT
- 241: Added New WT
- 242: Added New WT. Ongoing S1 & S2 debate on Architecture support.
- 243: Contribution at S3#25

| ID | WBS | Task | Duration | Start | Finish | Predecessors | Complete | Remaining | Baseline start | Baseline finish | Baseline duration | Total slack | Constraint | Resources | Work | Actual work | Text1 | Text2 | Text7 | Text9 | Text3 | Text4 | Text5 | Text6 | Text8 |
| --- | --- | --- | --- | --- | --- | --- | --- | --- | --- | --- | --- | --- | --- | --- | --- | --- | --- | --- | --- | --- | --- | --- | --- | --- | --- |
| 244 | 38.14 | **Retrieval of Terminal capabilities** | 634d | 2000-07-11 A | 2002-12-13 A |  | 100% |  | 2000-07-11 | 2002-12-13 | 634d |  |  | S2 | 10808h | 10808h | OSA1-TC | Ser | TSG | 1433 |  |  |  |  |  |
| 245 | 38.14.1 | Stage 1 | 132d | 2000-07-11 A | 2001-01-10 A |  | 100% |  | 2000-07-11 | 2001-01-10 | 132d |  | finish no earlier than 2001-01-10 | S1 | 1056h | 1056h |  | Ser | TSG | 1434 | 22.127 | Jörg Swetina, SIEMENS AG |  |  |  |
| 246 | 38.14.2 | Stages 2 and 3 | 321d | 2001-09-21 A | 2002-12-13 A | 245 | 100% |  | 2001-09-21 | 2002-12-13 | 321d |  | finish no earlier than 2002-12-13 | N5 | 2568h | 2568h |  | Ser | TSG | 1436 | 29.198, 29.998 | Ard-Jan MOERDIJK (Ericsson) | Ard.Jan.Moerdijk@eln.ericsson.se |  |  |
| 247 | 38.14.3 | Provisionning of the terminal capabilities | 445d | 2001-04-02 A | 2002-12-13 A |  | 100% |  | 2001-04-02 | 2001-11-30 | 175d |  | finish no earlier than 2002-12-13 | T2 | 3560h | 3560h |  |  | TSG | 2122 | 23.057 |  |  |  |  |
| 248 | 33 | **Handling of early UEs** | 210d? | 2002-09-09 A | 2003-06-27 |  | 56% | 92.66d? | 2002-10-07 | 2003-06-27 | 190d? | 215d |  | S2 | 4480h | 2503.35h | LATE_UE |  | TSG |  |  |  |  | Rel-6 | Alain |
| 249 | 33.1 | Feasibility Study | 50d? | 2002-10-07 A | 2002-12-13 A |  | 100% |  | 2002-10-07 | 2002-12-13 | 50d? |  | finish no earlier than 2002-12-13 | S2 | 400h | 400h |  |  | WG |  |  |  |  |  |  |
| 250 | 33.2 | Stage 2 | 125d? | 2003-01-06 A | 2003-06-27 |  | 24% | 95d? | 2003-01-06 | 2003-06-27 | 125d? | 215d | start no earlier than 2003-01-06 | S2 | 1000h | 240h |  |  | WG |  |  |  |  |  |  |
| 251 | 9.5 | FS for the Early Mobile Handling in UTRAN | 195d | 2002-09-09 A | 2003-06-06 |  | 65% | 68.25d | 2002-09-09 | 2003-03-14 | 135d | 230d | finish no earlier than 2003-06-06 | R2 | 1560h | 1014h | FSEarlyUE |  | TSG |  |  | Alan Law, Vodafone Ltd |  | Rel-6 |  |
| 252 | 39 | **Addition of frequency bands to GSM** | 306d | 2002-06-28 A | 2003-08-29 |  | 8% | 282.04d | 2002-06-28 | 2003-12-19 | 386d | 170d |  | GP | 7760h | 607.71h | TAPS |  | TSG |  |  | Torben Themsen |  | Rel-6 | Paolo |
| 253 | 39.1 | **Addition of frequency bands to GSM – Changes to core specs** | 26d | 2002-11-15 A | 2002-12-20 A |  | 100% |  | 2002-11-15 | 2002-12-20 | 26d |  |  | G1 | 416h | 416h | TAPS-Specs |  | TSG |  |  | Torben Themsen |  | Rel-6 |  |
| 254 | 39.1.1 | Changes to core specs | 26d | 2002-11-15 A | 2002-12-20 A |  | 100% |  | 2002-11-15 | 2002-12-20 | 26d |  | finish no earlier than 2002-12-20 | G1 | 208h | 208h |  |  |  |  |  |  |  |  |  |
| 255 | 39.2 | **Addition of frequency bands to GSM – Changes for conformance tests** | 306d | 2002-06-28 | 2003-08-29 |  |  |  | 2002-06-28 | 2003-12-19 | 386d | 170d |  | G4 | 4896h |  | TAPS-Conf |  |  |  |  | Torben Themsen |  |  |  |
| 256 | 39.2.1 | 51.010-1 Add testing | 306d | 2002-06-28 | 2003-08-29 |  |  |  | 2002-06-28 | 2003-12-19 | 386d | 170d | finish no earlier than 2003-08-29 | G4 | 2448h |  |  |  |  |  |  |  |  |  |  |
| 257 | 40 | **Seamless support of streaming services in A/Gb mode** | 1035d? | 2000-01-03 A | 2003-12-19 |  | 83% | 176.47d? | 2000-01-03 | 2003-12-19 | 1035d? | 90d |  | GP | 34008h | 22255.7h | SSStrea |  | TSG |  |  | José Luis Carrizo Martínez, Vodafone |  | Rel-6 | Paolo |
| 258 | 40.1 | **Identification of requirements for streaming** | 1d? | 2003-06-27 A | 2003-06-27 |  | 90% | 0.1d? | 2003-06-27 | 2003-06-27 | 1d? | 215d |  | G1 | 16h | 15.2h |  |  |  |  |  |  |  |  |  |
| 259 | 35.1.1 | Requirements | 1d? | 2003-06-27 A | 2003-06-27 |  | 90% | 0.1d? | 2003-06-27 | 2003-06-27 | 1d? | 215d | start no earlier than 2003-06-27 | G1 | 8h | 7.2h |  |  |  |  |  |  |  |  |  |
| 260 | 40.2 | **Performance study of cell change mechanisms** | 910d? | 2000-01-03 A | 2003-06-27 |  | 90% | 91d? | 2000-01-03 | 2003-06-27 | 910d? | 215d |  | G1 | 29120h | 19748.8h |  |  |  |  |  |  |  |  |  |
| 261 | 35.2.1 | Performance of NACC | 910d? | 2000-01-03 A | 2003-06-27 |  | 90% | 91d? | 2000-01-03 | 2003-06-27 | 910d? | 215d | finish no earlier than 2003-06-27 | G1 | 7280h | 6552h |  |  |  |  |  |  |  |  |  |
| 262 | 35.2.2 | Performance of cell change in DTM for the PS domain | 910d? | 2000-01-03 A | 2003-06-27 |  | 90% | 91d? | 2000-01-03 | 2003-06-27 | 910d? | 215d | finish no earlier than 2003-06-27 | G1 | 7280h | 6552h |  |  |  |  |  |  |  |  |  |
| 263 | 35.2.3 | Handover | 910d? | 2000-01-03 A | 2003-06-27 |  | 90% | 91d? | 2000-01-03 | 2003-06-27 | 910d? | 215d | finish no earlier than 2003-06-27 | G1 | 7280h | 6552h |  |  |  |  |  |  |  |  |  |
| 264 | 40.3 | **Reduction of service interruption times and packet loss during mobility procedures** | 1d? | 2003-06-27 A | 2003-06-27 |  | 50% | 0.5d? | 2003-06-27 | 2003-06-27 | 1d? | 215d |  | G2 | 40h | 20h |  |  |  |  |  |  |  |  |  |
| 265 | 35.3.1 | Optimisations of existing mechanisms/procedures | 1d? | 2003-06-27 A | 2003-06-27 |  | 50% | 0.5d? | 2003-06-27 | 2003-06-27 | 1d? | 215d | start no earlier than 2003-06-27 | G2 | 8h | 4h |  |  |  |  |  |  |  |  |  |
| 266 | 35.3.2 | Inter-system NACC | 1d? | 2003-06-27 A | 2003-06-27 |  | 50% | 0.5d? | 2003-06-27 | 2003-06-27 | 1d? | 215d | start no earlier than 2003-06-27 | G2 | 8h | 4h |  |  |  |  |  |  |  |  |  |
| 267 | 35.3.3 | PS Handover (within GERAN and between GERAN and UTRAN) | 1d? | 2003-06-27 A | 2003-06-27 |  | 50% | 0.5d? | 2003-06-27 | 2003-06-27 | 1d? | 215d | start no earlier than 2003-06-27 | G2 | 8h | 4h |  |  |  |  |  |  |  |  |  |
| 268 | 35.3.4 | Dependency to other features | 1d? | 2003-06-27 A | 2003-06-27 |  | 50% | 0.5d? | 2003-06-27 | 2003-06-27 | 1d? | 215d | start no earlier than 2003-06-27 | G2 | 8h | 4h |  |  |  |  |  |  |  |  |  |

Notes:
- 247: According to T2 SWG1 M. Cataldo this is automatically supported by the MExE support of UAProf therefore 100% complete
- 253: Ready
- 255: Not started
- 258: Started
- 260: Started
- 264: Started

| ID | WBS | Task | Duration | Start | Finish | Complete | Remaining | Baseline start | Baseline finish | Baseline duration | Total slack | Constraint | Resources | Work | Actual work | Text3 | Text4 | Text5 | Text1 | Text6 | Text7 | Text8 | Text2 | Text9 |
| --- | --- | --- | --- | --- | --- | --- | --- | --- | --- | --- | --- | --- | --- | --- | --- | --- | --- | --- | --- | --- | --- | --- | --- | --- |
| 269 | 40.5 | **MS conformance testing** | 1d? | 2003-12-19 | 2003-12-19 |  |  | 2003-12-19 | 2003-12-19 | 1d? | 90d |  | G4,G5 | 16h |  |  |  |  |  |  |  |  |  |  |
| 270 | 35.4.1 | MS conformance tests | 1d? | 2003-12-19 | 2003-12-19 |  |  | 2003-12-19 | 2003-12-19 | 1d? | 90d | start no earlier than 2003-12-19 | G4,G5 | 8h |  |  |  |  |  |  |  |  |  |  |
| 271 | 35.5 | GERAN A/Gb mode security enhancements | 261d? | 2002-09-26 A | 2003-09-25 | 10% | 234.9d? | 2002-12-09 | 2003-12-08 | 261d? | 151d | finish no earlier than 2003-09-25 | S3 | 2088h | 208.8h | 33.102 | Peter Howard, Vodafone | peter.howard@vodafone.com |  |  |  |  |  |  |
| 272 | 41 | Performance characterisation of default codecs for PS conversational multimedia application | 271d | 2002-09-13 A | 2003-09-26 | 20% | 216.8d | 2002-09-11 | 2003-06-20 | 203d | 150d | finish no earlier than 2003-09-26 | S4 | 2168h | 433.6h | TR 26.9yz | Pasi Ojala (Nokia) |  | CODCAR | Rel-6 | TSG | Paolo |  |  |
| 273 | 42 | Study of Feature Interactions Requirements | 82d | 2002-11-08 A | 2003-03-03 | 20% | 65.6d | 2002-11-08 | 2003-03-03 | 82d | 299d | start no earlier than 2002-11-08 | S1 | 656h | 131.2h | TR 21.xyz |  |  | FINTER | Rel-6 | TSG | Michael |  |  |
| 274 | 43 | Study on Privacy Capability | 82d | 2002-11-08 A | 2003-03-03 | 15% | 69.7d | 2002-11-08 | 2003-03-03 | 82d | 299d | start no earlier than 2002-11-08 | S1 | 656h | 98.4h | TR 21.xyz | Liz Daniel, Lucent |  | PrivCap | Rel-6 | TSG | Michael |  |  |
| 275 | 44 | **Rel-6 OAM&P** | 462d? | 2002-06-12 A | 2004-03-18 | 22% | 359.7d? | 2002-06-12 | 2003-09-25 | 337d? | 26d |  | S5 | 27808h | 5808.8h | 32-series | Michael TRUSS (Motorola) | Michael.Truss@MOTOROLA.COM | OAM | Rel-6 | TSG | Adrian |  |  |
| 276 | 44.1 | Rel6 Principles, high level Requirements and Architecture | 396d | 2002-09-12 A | 2004-03-18 | 20% | 316.8d | 2002-09-12 | 2003-09-25 | 271d | 26d | finish no earlier than 2004-03-18 | S5 | 3168h | 633.6h | 32.101, 32.102 | Michael TRUSS (Motorola) | Michael.Truss@MOTOROLA.COM | OAM-AR |  | TSG |  | BCaM |  |
| 277 | 44.2 | Rel6 Performance Management | 396d | 2002-09-12 A | 2004-03-18 | 20% | 316.8d | 2002-09-12 | 2003-09-25 | 271d | 26d | finish no earlier than 2004-03-18 | S5 | 3168h | 633.6h | 32.41x, 52.402 | Christian TOCHE (Nortel Networks) | toche@NORTELNETWORKS.COM | OAM-PM |  | TSG |  | BCaM |  |
| 278 | 44.3 | **Rel6 User Equipment Management** | 426d? | 2002-08-01 A | 2004-03-18 | 11% | 378.56d? | 2002-08-01 | 2003-09-25 | 301d? | 26d |  | S5 | 10912h | 1215.2h | 32.150, 27.150 (T2), 32.802 | John Mudge (Vodafone) | john.mudge@vf.vodafone.co.uk | OAM-UEM |  | TSG |  |  |  |
| 279 | 39.3.1 | UEM requirements and architecture; Stages 1 and 2 | 396d? | 2002-09-12 A | 2004-03-18 | 20% | 316.8d? | 2002-09-12 | 2003-09-25 | 271d? | 26d | finish no earlier than 2004-03-18 | S5 | 3168h | 633.6h | 32.150 (SA5) | John Mudge (Vodafone) | john.mudge@vf.vodafone.co.uk |  |  | TSG |  |  |  |
| 280 | 39.3.2 | UEM protocol specification; Stage 3 | 271d? | 2002-09-12 A | 2003-09-25 | 5% | 257.45d? | 2002-09-12 | 2003-09-25 | 271d? | 151d | finish no earlier than 2003-09-25 | T2 | 2168h | 108.4h | 27.150 (T2) |  |  |  |  | TSG |  |  |  |
| 281 | 39.3.3 | Release 6 User Equipment Management: Security aspects | 301d? | 2002-08-01 A | 2003-09-25 | 5% | 285.95d? | 2002-08-01 | 2003-09-25 | 301d? | 151d | finish no earlier than 2003-09-25 | S3 | 2408h | 120.4h |  | Peter Howard (Vodafone) | peter.howard@vodafone.com | OAM-UEM-SEC |  | TSG |  |  |  |
| 282 | 44.4 | Rel6 Network Infrastructure Management | 396d | 2002-09-12 A | 2004-03-18 | 15% | 336.6d | 2002-09-12 | 2003-09-25 | 271d | 26d | finish no earlier than 2004-03-18 | S5 | 3168h | 475.2h | 32.6xy, 32.3xy | Thomas TOVINGER (Ericsson) | Thomas.Tovinger@emw.ericsson.se | OAM-NIM |  | TSG |  |  |  |
| 283 | 44.5 | Rel6 Trace Management | 462d | 2002-06-12 A | 2004-03-18 | 55% | 207.9d | 2002-06-12 | 2003-09-25 | 337d | 26d | finish no earlier than 2004-03-18 | S5 | 3696h | 2032.8h | 32.42x, 52.008 | Christian TOCHE (Nortel Networks) | toche@NORTELNETWORKS.COM | OEM-Trace |  | TSG |  |  |  |
| 284 | 40 | **Charging Management** | 346d? | 2002-11-21 A | 2004-03-18 | 10% | 311.39d? | 2002-11-21 | 2003-09-25 | 221d? | 26d |  | S5 | 12264h | 1226.91h | 32.2xy | Karl-Heinz NENNER (T-Mobile) | karl-heinz.nenner@t-mobile.de | CH | Rel-6 | TSG | Adrian |  |  |
| 285 | 40.1 | Charging Management for Bearer level | 345d? | 2002-11-22 A | 2004-03-18 | 5% | 327.75d? | 2002-11-22 | 2003-09-25 | 220d? | 26d | finish no earlier than 2004-03-18 | S5 | 2760h | 138h |  | Benni ALEXANDER (Nokia) |  | CH-BC |  | TSG |  |  |  |
| 286 | 40.2 | Charging Management for the IMS | 345d? | 2002-11-22 A | 2004-03-18 | 5% | 327.75d? | 2002-11-22 | 2003-09-25 | 220d? | 26d | finish no earlier than 2004-03-18 | S5 | 2760h | 138h |  | Ariel SHARON (Lucent) |  | CH-IC |  | TSG |  |  |  |
| 287 | 40.3 | Charging Management for the Service domain | 345d? | 2002-11-22 A | 2004-03-18 | 5% | 327.75d? | 2002-11-22 | 2003-09-25 | 220d? | 26d | finish no earlier than 2004-03-18 | S5 | 2760h | 138h |  | Gerald GÖRMER (Siemens) |  | CH-SC |  | TSG |  |  |  |
| 288 | 40.4 | Overall architectural aspects of IP flow based bearer level charging | 152d? | 2002-11-21 A | 2003-06-20 | 44% | 85d? | 2002-11-21 | 2003-06-20 | 152d? | 220d | finish no earlier than 2003-06-20 | S2 | 1216h | 536h |  |  |  |  |  |  |  |  |  |
| 289 | 13 | **Rel-6 UICC/USIM enhancements and interworking** | 778d | 2000-09-25 A | 2003-09-17 | 58% | 325.78d | 2000-09-25 | 2003-09-17 | 778d | 157d |  | T3 | 24200h | 12454.3h |  |  |  | USAT1 | NA | TSG | Claus | Ter | 1800 |
| 290 | 13.1 | **UICC API** | 391d | 2002-03-20 A | 2003-09-17 | 25% | 292.05d | 2002-03-20 | 2003-09-17 | 391d | 157d |  | T3 | 6912h | 1749.19h |  |  |  | USAT1-API | NA |  |  | Ter | 1802 |
| 291 | 13.1.1 | Java API Test specification | 133d | 2002-03-20 A | 2002-09-20 | 90% | 13.3d | 2002-03-20 | 2002-09-20 | 133d | 415d | finish no earlier than 2002-09-20 | T3 | 1064h | 957.6h |  | Mario Pérez (Microelectrónica Española) |  |  |  |  |  |  |  |
| 292 | 13.1.2 | Java API Test specification (TS 43.019 Rel-5) | 340d | 2002-05-30 | 2003-09-17 |  |  | 2002-05-30 | 2003-09-17 | 340d | 157d | finish no earlier than 2003-09-17 | T3 | 2720h |  |  | Mario Pérez (Microelectrónica Española) |  |  | Rel-5 |  |  |  |  |

Notes:
- 269: Not started
- 271: Possible changes to 33.102 or new specification needed.
- 275: TSG approval 09/03->03/04
- 280: created 25/11/02
- 281: created 15/01/03
- 284: TSG approval 09/03->03/04. Changed WID
- 285: Changed WID
- 286: Changed WID
- 287: Changed WID
- 290: 8/3/2001: test spec is based on R99 core spec, so deleted from Workplan

| ID | WBS | Task | Duration | Start | Finish | Complete | Remaining | Baseline start | Baseline finish | Baseline duration | Total slack | Constraint | Resources | Work | Actual work | Text6 | Text8 | Text1 | Text2 | Text7 | Text9 | Text4 | Text3 | Text5 |
| --- | --- | --- | --- | --- | --- | --- | --- | --- | --- | --- | --- | --- | --- | --- | --- | --- | --- | --- | --- | --- | --- | --- | --- | --- |
| 293 | 41.2 | **Rel-6 USIM toolkit enhancements** | 525d | 2000-09-25 A | 2002-09-27 | 80% | 106.64d | 2000-09-25 | 2002-09-27 | 525d | 410d |  | T3 | 14160h | 8886.88h | NA | Claus |  |  |  |  |  |  |  |
| 294 | 41.2.1 | **C SIM API** | 525d | 2000-09-25 A | 2002-09-27 | 80% | 106.64d | 2000-09-25 | 2002-09-27 | 525d | 410d |  | T3 | 9960h | 7936.88h | Rel-6 |  | USAT1-API-MULTOS | Ter | TSG | 2031 |  |  |  |
| 295 | 41.2.1.1 | Specification | 525d | 2000-09-25 A | 2002-09-27 A | 100% |  | 2000-09-25 | 2002-09-27 | 525d |  | finish no earlier than 2002-09-27 | T3 | 4200h | 4200h |  |  |  | Ter | TSG | 2032 | Neil Livingston – Aspects Software |  |  |
| 296 | 41.2.1.2 | Test specification | 195d | 2001-01-01 A | 2001-09-28 | 25% | 146.25d | 2001-01-01 | 2001-09-28 | 195d | 670d | finish no earlier than 2001-09-28 | T3 | 1560h | 390h |  |  |  | Ter | TSG | 2033 | Neil Livingston – Aspects Software |  |  |
| 297 | 42 | **Packet Switched Streaming Services Rel-6** | 285d? | 2002-11-18 A | 2003-12-19 | 22% | 221.19d? | 2002-11-11 | 2003-06-20 | 160d | 90d |  | S4 | 5784h | 1294.93h | Rel-6 | Paolo | PSSrel6 |  | TSG |  | Olle Franceschi (Ericsson) |  |  |
| 298 | 42.1 | Stage 1 | 86d? | 2002-11-18 A | 2003-03-17 | 80% | 17.2d? |  |  |  | 289d | finish no earlier than 2003-03-17 | S1 | 688h | 550.4h |  |  |  |  | TSG |  |  | 22.233 |  |
| 299 | 42.2 | Stage 2 | 86d? | 2003-03-10 | 2003-07-07 |  |  |  |  |  | 209d | start no earlier than 2003-03-10 | S2 | 688h |  |  |  |  |  |  |  |  |  |  |
| 300 | 42.3 | Stage 3 | 266d? | 2002-12-13 A | 2003-12-19 | 11% | 236.74d? |  |  |  | 90d | start no earlier than 2002-12-13 | S4 | 2128h | 234.08h |  | Paolo | PSSrel6 |  | WG |  | Olle Franceschi (Ericsson) | 26.233, 26.234, 26.244, 26.245, 26.246 |  |
| 301 | 43 | Network Domain Security; Authentication Framework (NDS/AF) | 481d? | 2002-02-15 A | 2003-12-19 | 10% | 432.9d? |  |  |  | 90d | finish no earlier than 2003-12-19 | S3 | 3848h | 384.8h | Rel-6 |  | SEC1-NDS-AF |  | TSG |  | Tommi Viitanen, Nokia |  | tommi.viitanen@nokia.com |
| 302 | 44 | AMR-WB extension for high audio quality | 206d | 2002-12-13 A | 2003-09-26 | 12% | 181.28d | 2002-11-11 | 2003-06-20 | 160d | 150d | finish no earlier than 2003-09-26 | S4 | 1648h | 197.76h | Rel-6 | Paolo | AMRWB+ |  | WG |  | Janne Vainio (Nokia) |  |  |
| 303 | 45 | Single Antenna Receiver Interference Cancellation (SAIC) | 220.92d? | 2002-11-15 A | 2003-11-21 | 25% | 165.69d? | 2002-11-15 | 2003-06-27 | 161d? | 110d | finish no earlier than 2003-11-21 | GP; G1 | 3534.72h | 883.68h | Rel-6 |  | SAIC |  | TSG |  | Marc Grant, Cingular Wireless |  |  |
| 304 | 46 | **Support of Conversational Services in A/Gb mode via the PS domain** | 316d? | 2003-02-07 A | 2004-04-23 | 2% | 309.98d? | 2003-02-07 | 2004-04-30 | 321d? | 0d |  | GP | 7752h | 130.53h | Rel-6 |  | SCSAGB |  | TSG |  | David Bladsjö, Ericsson |  |  |
| 305 | 46.1 | Creation of a TR | 206d? | 2003-02-07 A | 2003-11-21 | 5% | 195.7d? | 2003-02-07 | 2003-11-28 | 211d? | 110d | finish no earlier than 2003-11-21 | GP | 1648h | 82.4h |  |  | SCSAGB-TR |  | TSG |  | David Bladsjö, Ericsson |  |  |
| 306 | 46.2 | Stage 2 | 111d? | 2003-11-21 | 2004-04-23 |  |  | 2003-02-07 | 2004-04-30 | 321d? | 0d | finish no earlier than 2004-04-23 | GP | 888h |  |  |  | SCSAGB-Stage2 |  | TSG |  | David Bladsjö, Ericsson |  |  |
| 307 | 46.3 | Radio Channel Support | 56d? | 2004-02-06 | 2004-04-23 |  |  | 2003-02-07 | 2004-04-30 | 321d? | 0d | finish no earlier than 2004-04-23 | GP | 448h |  |  |  | SCSAGB-RCS |  | TSG |  | David Bladsjö, Ericsson |  |  |
| 308 | 46.4 | Definition of radio resource management functionality | 56d? | 2004-02-06 | 2004-04-23 |  |  | 2003-02-07 | 2003-09-19 | 160.5d? | 0d | finish no earlier than 2004-04-23 | GP; G2 | 896h |  |  |  | SCSAGB-RRM |  | TSG |  | David Bladsjö, Ericsson |  |  |
| 309 | 46.5 | PS Handover | 56d? | 2004-02-06 | 2004-04-23 |  |  | 2003-02-07 | 2004-04-30 | 321d? | 0d | finish no earlier than 2004-04-23 | GP | 448h |  |  |  | SCSAGB-PSH |  | TSG |  | David Bladsjö, Ericsson |  |  |
| 310 | 46.6 | Modifications to FLO | 56d? | 2004-02-06 | 2004-04-23 |  |  | 2003-02-07 | 2003-09-19 | 160.5d? | 0d | finish no earlier than 2004-04-23 | GP; G2 | 896h |  |  |  | SCSAGB-FLO |  | TSG |  | David Bladsjö, Ericsson |  |  |
| 311 | 47 | **Enhancement of dialled service for CAMEL** | 126d? | 2003-03-28 | 2003-09-19 |  |  |  |  |  | 155d |  | S1 | 2016h |  | Rel-6 | Andrijana | EDCAMEL |  | TSG |  | Craig Bishop, Samsung Electronics Research Institute |  |  |
| 312 | 47.1 | Stages 2 and 3 | 126d? | 2003-03-28 | 2003-09-19 |  |  |  |  |  | 155d | finish no earlier than 2003-09-19 | N2 | 1008h |  | Rel-6 |  |  |  |  |  |  |  |  |

Notes:
- 295: 30/12/2000: completion amount updated
- 298: 2nd resp SA4
- 299: Stage 2 to be done by SA2 (e-mail from Kari)
- 301: WID approved SA#19. Work started after FS approved SA#18
- 303: Ongoing
- 305: Started
- 306: Not Started
- 307: Not Started
- 308: Not Started
- 309: Not Started
- 310: Not Started
